# Assets aquisition road map schedule

Schedule from MS Project, 2015-08-01 to 2016-08-01, status date 2015-10-08, 24 hours a day, A marks actual dates.
еткмкермнр

## Calendars

- 24 Hours: Mon-Sun 00:00-24:00.

## Schedule

| ID | WBS | Task | Type | Duration | Start | Finish | Predecessors | Complete | Remaining | Total slack | Free slack | Constraint | Ответственный | Text2 |
| --- | --- | --- | --- | --- | --- | --- | --- | --- | --- | --- | --- | --- | --- | --- |
| 1 | 1 | Search opportunity in KZ region | milestone | 0d | 2015-08-01 A | 2015-08-01 A |  | 100% |  |  |  | start no earlier than 2015-08-01 | Name |  |
| 2 | 2 | **Best Case - Jupiter** |  | 295d | 2015-08-01 A | 2016-05-22 |  | 30% | 207d | 71d |  |  | Name |  |
| 3 | 2.1 | Summaries key characteristics |  | 10d | 2015-08-01 A | 2015-08-11 A | 1 | 100% |  |  |  |  | Name | A1 |
| 4 | 2.2 | Screen and Priorities |  | 7d | 2015-08-11 A | 2015-08-18 A | 3 | 100% |  |  |  |  | Name | A2 |
| 5 | 2.3 | Pursue - OK |  | 3d | 2015-08-18 A | 2015-08-21 A | 4 | 100% |  |  |  |  | Name | A3 |
| 6 | 2.4 | Preliminary discussions |  | 7d | 2015-08-21 A | 2015-08-28 A | 5 | 100% |  |  |  |  | Name | B1 |
| 7 | 2.5 | Confidentiality agreement |  | 7d | 2015-08-28 A | 2015-09-04 A | 6 | 100% |  |  |  |  | Name | B2 |
| 8 | 2.6 | Accessing data |  | 10d | 2015-09-04 A | 2015-09-14 A | 7 | 100% |  |  |  |  | Name | B3 |
| 9 | 2.7 | Assessment of reserves and preliminary tech DD |  | 10d | 2015-09-14 A | 2015-09-24 A | 8 | 100% |  |  |  |  | Name | B4 |
| 10 | 2.8 | Development planing cost/production |  | 10d | 2015-09-24 A | 2015-10-04 A | 9 | 100% |  |  |  |  | Name | B5 |
| 11 | 2.9 | Economic evaluation |  | 20d | 2015-10-04 A | 2015-10-24 A | 10 | 100% |  |  |  |  | Name | B6 |
| 12 | 2.10 | Pursue - OK |  | 3d | 2015-10-24 A | 2015-10-27 A | 11 | 100% |  |  |  |  | Name | B7 |
| 13 | 2.11 | Risk Assessment |  | 10d | 2015-10-27 A | 2015-11-06 | 12 | 10% | 9d | 10d | 0d |  | Name | B8 |
| 14 | 2.12 | Assurance event - Lo risk |  | 7d | 2015-11-06 | 2015-11-13 | 13 |  |  | 10d | 0d |  | Name | B9 |
| 15 | 2.13 | Business Case with Board support |  | 10d | 2015-11-13 | 2015-11-23 | 14 |  |  | 10d | 0d |  | Name | C1 |
| 16 | 2.14 | Negotiate terms and conditions |  | 15d | 2015-11-23 | 2015-12-08 | 15 |  |  | 10d | 0d |  | Name | C2 |
| 17 | 2.15 | Economic evaluation updating |  | 7d | 2015-12-08 | 2015-12-15 | 16 |  |  | 10d | 0d |  | Name | C3 |
| 18 | 2.16 | Assurance event - OK |  | 3d | 2015-12-15 | 2015-12-18 | 17 |  |  | 39d | 0d |  | Name | C4 |
| 19 | 2.17 | Update Business proposal |  | 7d | 2015-12-18 | 2015-12-25 | 18 |  |  | 39d | 0d |  | Name | C5 |
| 20 | 2.18 | Board approval - OK |  | 7d | 2015-12-25 | 2016-01-01 | 19 |  |  | 71d | 0d |  | Name | C6 |
| 21 | 2.19 | MOU signing |  | 7d | 2016-01-01 | 2016-01-08 | 20 |  |  | 71d | 0d |  | Name | D1 |
| 22 | 2.20 | Final DueDilligence (Tech, Legal, Fin) |  | 30d | 2016-01-08 | 2016-02-07 | 21 |  |  | 71d | 0d |  | Name | D2 |
| 23 | 2.21 | Sale purchase agreement signing |  | 15d | 2016-02-07 | 2016-02-22 | 22 |  |  | 71d | 0d |  | Name | D3 |
| 24 | 2.22 | Government procedures (deal approval) |  | 90d | 2016-02-22 | 2016-05-22 | 23 |  |  | 71d | 0d |  | Name | D4 |
| 25 | 2.23 | Deal close | milestone | 0d | 2016-05-22 | 2016-05-22 | 24 |  |  | 71d |  |  | Name |  |

| ID | WBS | Task | Type | Duration | Start | Finish | Predecessors | Total slack | Free slack | Constraint | Ответственный | Text2 |
| --- | --- | --- | --- | --- | --- | --- | --- | --- | --- | --- | --- | --- |
| 26 | 3 | **Assurance event - High risk can be reduced** |  | 279d | 2015-10-27 | 2016-08-01 |  | 0d |  |  | Name | B9 |
| 27 | 3.1 | Development planing cost/production |  | 7d | 2015-10-27 | 2015-11-03 | 12 | 0d |  |  | Name | B5 |
| 28 | 3.2 | Economic evaluation |  | 7d | 2015-11-03 | 2015-11-10 | 27 | 0d |  |  | Name | B6 |
| 29 | 3.3 | Pursue - OK |  | 3d | 2015-11-10 | 2015-11-13 | 28 | 0d |  |  | Name | B7 |
| 30 | 3.4 | Risk Assessment |  | 7d | 2015-11-13 | 2015-11-20 | 29 | 0d |  |  | Name | B8 |
| 31 | 3.5 | Assurance event - Lo risk |  | 3d | 2015-11-20 | 2015-11-23 | 30 | 0d |  |  | Name | B9 |
| 32 | 3.6 | Business Case with Board support |  | 10d | 2015-11-23 | 2015-12-03 | 31 | 0d |  |  | Name | C1 |
| 33 | 3.7 | Negotiate terms and conditions |  | 15d | 2015-12-03 | 2015-12-18 | 32 | 0d |  |  | Name | C2 |
| 34 | 3.8 | Economic evaluation updating |  | 7d | 2015-12-18 | 2015-12-25 | 33 | 0d |  |  | Name | C3 |
| 35 | 3.9 | Assurance event - Economic OK |  | 3d | 2015-12-25 | 2015-12-28 | 34 | 217d |  |  | Name | C4 |
| 36 | 3.10 | Update Business proposal |  | 7d | 2015-12-25 | 2016-01-01 | 34 | 32d | 0d |  | Name | C5 |
| 37 | 3.11 | Board approval - OK |  | 7d | 2016-01-01 | 2016-01-08 | 36 | 64d | 0d |  | Name | C6 |
| 38 | 3.12 | MOU signing |  | 7d | 2016-01-08 | 2016-01-15 | 37 | 64d | 0d |  | Name | D1 |
| 39 | 3.13 | Final DueDilligence (Tech, Legal, Fin) |  | 30d | 2016-01-15 | 2016-02-14 | 38 | 64d | 0d |  | Name | D2 |
| 40 | 3.14 | Sale purchase agreement signing |  | 15d | 2016-02-14 | 2016-02-29 | 39 | 64d | 0d |  | Name | D3 |
| 41 | 3.15 | Government procedures (deal approval) |  | 90d | 2016-02-29 | 2016-05-29 | 40 | 64d | 0d |  | Name | D4 |
| 42 | 3.16 | Deal close | milestone | 0d | 2016-05-29 | 2016-05-29 | 41 | 64d |  |  | Name |  |
| 43 | 3.17 | **Assurance event - New terms and condition** |  | 220d | 2015-12-25 | 2016-08-01 |  | 0d |  |  | Name | C4 |
| 44 | 3.17.1 | Negotiate terms and conditions |  | 15d | 2015-12-25 | 2016-01-09 | 34 | 0d |  | finish no earlier than 2015-12-08 | Name | C2 |
| 45 | 3.17.2 | Economic evaluation updating |  | 7d | 2016-01-09 | 2016-01-16 | 44 | 0d |  | finish no earlier than 2015-12-15 | Name | C3 |
| 46 | 3.17.3 | Assurance event - Economic OK |  | 3d | 2016-01-16 | 2016-01-19 | 45 | 0d |  | finish no earlier than 2015-12-18 | Name | C4 |
| 47 | 3.17.4 | Update Business proposal |  | 7d | 2016-01-19 | 2016-01-26 | 46 | 0d |  |  | Name | C5 |
| 48 | 3.17.5 | Board approval - OK |  | 7d | 2016-01-26 | 2016-02-02 | 47 | 0d |  |  | Name | C6 |
| 49 | 3.17.6 | MOU signing |  | 7d | 2016-02-02 | 2016-02-09 | 48 | 39d | 0d |  | Name | D1 |
| 50 | 3.17.7 | Final DueDilligence (Tech, Legal, Fin) |  | 30d | 2016-02-09 | 2016-03-10 | 49 | 39d | 0d |  | Name | D2 |
| 51 | 3.17.8 | Sale purchase agreement signing |  | 15d | 2016-03-10 | 2016-03-25 | 50 | 39d | 0d |  | Name | D3 |
| 52 | 3.17.9 | Government procedures (deal approval) |  | 90d | 2016-03-25 | 2016-06-23 | 51 | 39d | 0d |  | Name | D4 |
| 53 | 3.17.10 | Deal close | milestone | 0d | 2016-06-23 | 2016-06-23 | 52 | 39d |  |  | Name |  |

| ID | WBS | Task | Type | Duration | Start | Finish | Predecessors | Total slack | Free slack | Constraint | Ответственный | Text2 |
| --- | --- | --- | --- | --- | --- | --- | --- | --- | --- | --- | --- | --- |
| 54 | 3.17.11 | **Board approval - NO (New terms and condition proposed)** |  | 181d | 2016-02-02 | 2016-08-01 |  | 0d |  |  | Name | C6 |
| 55 | 3.17.11.1 | Negotiate terms and conditions |  | 15d | 2016-02-02 | 2016-02-17 | 48 | 0d |  | finish no earlier than 2015-12-08 | Name | C2 |
| 56 | 3.17.11.2 | Economic evaluation updating |  | 7d | 2016-02-17 | 2016-02-24 | 55 | 0d |  | finish no earlier than 2015-12-15 | Name | C3 |
| 57 | 3.17.11.3 | Assurance event - Economic OK |  | 3d | 2016-02-24 | 2016-02-27 | 56 | 0d |  | finish no earlier than 2015-12-18 | Name | C4 |
| 58 | 3.17.11.4 | Update Business proposal |  | 7d | 2016-02-27 | 2016-03-05 | 57 | 0d |  | finish no earlier than 2015-12-25 | Name | C5 |
| 59 | 3.17.11.5 | Board approval - OK |  | 7d | 2016-03-05 | 2016-03-12 | 58 | 0d |  | finish no earlier than 2016-01-01 | Name | C6 |
| 60 | 3.17.11.6 | MOU signing |  | 7d | 2016-03-12 | 2016-03-19 | 59 | 0d |  |  | Name | D1 |
| 61 | 3.17.11.7 | Final DueDilligence (Tech, Legal, Fin) |  | 30d | 2016-03-19 | 2016-04-18 | 60 | 0d |  |  | Name | D2 |
| 62 | 3.17.11.8 | Sale purchase agreement signing |  | 15d | 2016-04-18 | 2016-05-03 | 61 | 0d |  |  | Name | D3 |
| 63 | 3.17.11.9 | Government procedures (deal approval) |  | 90d | 2016-05-03 | 2016-08-01 | 62 | 0d |  |  | Name | D4 |
| 64 | 3.17.11.10 | Deal close | milestone | 0d | 2016-08-01 | 2016-08-01 | 63 | 0d |  |  | Name |  |
| 65 | 3.18 | **Board approval - NO (New terms and condition proposed)** |  | 181d | 2016-01-01 | 2016-06-30 |  | 32d |  |  | Name | C6 |
| 66 | 3.18.1 | Negotiate terms and conditions |  | 15d | 2016-01-01 | 2016-01-16 | 36 | 32d | 0d | finish no earlier than 2015-12-08 | Name | C2 |
| 67 | 3.18.2 | Economic evaluation updating |  | 7d | 2016-01-16 | 2016-01-23 | 66 | 32d | 0d | finish no earlier than 2015-12-15 | Name | C3 |
| 68 | 3.18.3 | Assurance event - Economic OK |  | 3d | 2016-01-23 | 2016-01-26 | 67 | 32d | 0d | finish no earlier than 2015-12-18 | Name | C4 |
| 69 | 3.18.4 | Update Business proposal |  | 7d | 2016-01-26 | 2016-02-02 | 68 | 32d | 0d | finish no earlier than 2015-12-25 | Name | C5 |
| 70 | 3.18.5 | Board approval - OK |  | 7d | 2016-02-02 | 2016-02-09 | 69 | 32d | 0d | finish no earlier than 2016-01-01 | Name | C6 |
| 71 | 3.18.6 | MOU signing |  | 7d | 2016-02-09 | 2016-02-16 | 70 | 32d | 0d |  | Name | D1 |
| 72 | 3.18.7 | Final DueDilligence (Tech, Legal, Fin) |  | 30d | 2016-02-16 | 2016-03-17 | 71 | 32d | 0d |  | Name | D2 |
| 73 | 3.18.8 | Sale purchase agreement signing |  | 15d | 2016-03-17 | 2016-04-01 | 72 | 32d | 0d |  | Name | D3 |
| 74 | 3.18.9 | Government procedures (deal approval) |  | 90d | 2016-04-01 | 2016-06-30 | 73 | 32d | 0d |  | Name | D4 |
| 75 | 3.18.10 | Deal close | milestone | 0d | 2016-06-30 | 2016-06-30 | 74 | 32d |  |  | Name |  |
| 76 | 4 | **Assurance event - New terms and condition** |  | 220d | 2015-12-15 | 2016-07-22 |  | 10d |  |  | Name | C4 |
| 77 | 4.1 | Negotiate terms and conditions |  | 15d | 2015-12-15 | 2015-12-30 | 17 | 10d | 0d | finish no earlier than 2015-12-08 | Name | C2 |
| 78 | 4.2 | Economic evaluation updating |  | 7d | 2015-12-30 | 2016-01-06 | 77 | 10d | 0d | finish no earlier than 2015-12-15 | Name | C3 |
| 79 | 4.3 | Assurance event - Economic OK |  | 3d | 2016-01-06 | 2016-01-09 | 78 | 10d | 0d | finish no earlier than 2015-12-18 | Name | C4 |
| 80 | 4.4 | Update Business proposal |  | 7d | 2016-01-09 | 2016-01-16 | 79 | 10d | 0d |  | Name | C5 |
| 81 | 4.5 | Board approval - OK |  | 7d | 2016-01-16 | 2016-01-23 | 80 | 10d | 0d |  | Name | C6 |
| 82 | 4.6 | MOU signing |  | 7d | 2016-01-23 | 2016-01-30 | 81 | 49d | 0d |  | Name | D1 |
| 83 | 4.7 | Final DueDilligence (Tech, Legal, Fin) |  | 30d | 2016-01-30 | 2016-02-29 | 82 | 49d | 0d |  | Name | D2 |
| 84 | 4.8 | Sale purchase agreement signing |  | 15d | 2016-02-29 | 2016-03-15 | 83 | 49d | 0d |  | Name | D3 |
| 85 | 4.9 | Government procedures (deal approval) |  | 90d | 2016-03-15 | 2016-06-13 | 84 | 49d | 0d |  | Name | D4 |
| 86 | 4.10 | Deal close | milestone | 0d | 2016-06-13 | 2016-06-13 | 85 | 49d |  |  | Name |  |

| ID | WBS | Task | Type | Duration | Start | Finish | Predecessors | Total slack | Free slack | Constraint | Ответственный | Text2 |
| --- | --- | --- | --- | --- | --- | --- | --- | --- | --- | --- | --- | --- |
| 87 | 4.11 | **Board approval - NO (New terms and condition proposed)** |  | 181d | 2016-01-23 | 2016-07-22 |  | 10d |  |  | Name | C6 |
| 88 | 4.11.1 | Negotiate terms and conditions |  | 15d | 2016-01-23 | 2016-02-07 | 81 | 10d | 0d | finish no earlier than 2015-12-08 | Name | C2 |
| 89 | 4.11.2 | Economic evaluation updating |  | 7d | 2016-02-07 | 2016-02-14 | 88 | 10d | 0d | finish no earlier than 2015-12-15 | Name | C3 |
| 90 | 4.11.3 | Assurance event - Economic OK |  | 3d | 2016-02-14 | 2016-02-17 | 89 | 10d | 0d | finish no earlier than 2015-12-18 | Name | C4 |
| 91 | 4.11.4 | Update Business proposal |  | 7d | 2016-02-17 | 2016-02-24 | 90 | 10d | 0d | finish no earlier than 2015-12-25 | Name | C5 |
| 92 | 4.11.5 | Board approval - OK |  | 7d | 2016-02-24 | 2016-03-02 | 91 | 10d | 0d | finish no earlier than 2016-01-01 | Name | C6 |
| 93 | 4.11.6 | MOU signing |  | 7d | 2016-03-02 | 2016-03-09 | 92 | 10d | 0d |  | Name | D1 |
| 94 | 4.11.7 | Final DueDilligence (Tech, Legal, Fin) |  | 30d | 2016-03-09 | 2016-04-08 | 93 | 10d | 0d |  | Name | D2 |
| 95 | 4.11.8 | Sale purchase agreement signing |  | 15d | 2016-04-08 | 2016-04-23 | 94 | 10d | 0d |  | Name | D3 |
| 96 | 4.11.9 | Government procedures (deal approval) |  | 90d | 2016-04-23 | 2016-07-22 | 95 | 10d | 0d |  | Name | D4 |
| 97 | 4.11.10 | Deal close | milestone | 0d | 2016-07-22 | 2016-07-22 | 96 | 10d |  |  | Name |  |
| 98 | 5 | **Board approval - NO (New terms and condition proposed)** |  | 181d | 2015-12-25 | 2016-06-23 |  | 39d |  |  | Name | C6 |
| 99 | 5.1 | Negotiate terms and conditions |  | 15d | 2015-12-25 | 2016-01-09 | 19 | 39d | 0d | finish no earlier than 2015-12-08 | Name | C2 |
| 100 | 5.2 | Economic evaluation updating |  | 7d | 2016-01-09 | 2016-01-16 | 99 | 39d | 0d | finish no earlier than 2015-12-15 | Name | C3 |
| 101 | 5.3 | Assurance event - Economic OK |  | 3d | 2016-01-16 | 2016-01-19 | 100 | 39d | 0d | finish no earlier than 2015-12-18 | Name | C4 |
| 102 | 5.4 | Update Business proposal |  | 7d | 2016-01-19 | 2016-01-26 | 101 | 39d | 0d | finish no earlier than 2015-12-25 | Name | C5 |
| 103 | 5.5 | Board approval - OK |  | 7d | 2016-01-26 | 2016-02-02 | 102 | 39d | 0d | finish no earlier than 2016-01-01 | Name | C6 |
| 104 | 5.6 | MOU signing |  | 7d | 2016-02-02 | 2016-02-09 | 103 | 39d | 0d |  | Name | D1 |
| 105 | 5.7 | Final DueDilligence (Tech, Legal, Fin) |  | 30d | 2016-02-09 | 2016-03-10 | 104 | 39d | 0d |  | Name | D2 |
| 106 | 5.8 | Sale purchase agreement signing |  | 15d | 2016-03-10 | 2016-03-25 | 105 | 39d | 0d |  | Name | D3 |
| 107 | 5.9 | Government procedures (deal approval) |  | 90d | 2016-03-25 | 2016-06-23 | 106 | 39d | 0d |  | Name | D4 |
| 108 | 5.10 | Deal close | milestone | 0d | 2016-06-23 | 2016-06-23 | 107 | 39d |  |  | Name |  |
