# Lend Permit 2015

Schedule from MS Project, 2015-03-11 to 2015-06-26, costs in $, A marks actual dates.

## Calendars

- Стандартный: Mon-Fri 09:00-13:00, 14:00-18:00; Sat-Sun off.

## Resources

| Resource |
| --- |
| петров |
| Независимая лаборатория |
| Independent laboratory |

## Schedule

| ID | WBS | Task | Type | Duration | Start | Finish | Predecessors | Complete | Remaining | Total slack | Constraint | Resources | Work | Actual work | Cost | Actual cost |
| --- | --- | --- | --- | --- | --- | --- | --- | --- | --- | --- | --- | --- | --- | --- | --- | --- |
| 1 | 1 | **Land Permit activities** |  | 78d | 2015-03-11 A | 2015-06-26 |  | 60% | 30.97d | 0d |  |  | 56h | 56h | 4,182 | 1,271.2 |
| 2 | 1.1 | **Land allocation** |  | 40d | 2015-03-11 A | 2015-05-05 A |  | 100% |  |  |  |  | 56h | 56h |  |  |
| 3 | 1.1.1 | Application for land acquisition |  | 1d | 2015-03-11 A | 2015-03-11 A |  | 100% |  |  | start no earlier than 2015-01-01 |  |  |  |  |  |
| 4 | 1.1.2 | Obtaining of land allocation form | manual | 3d | 2015-03-12 A | 2015-03-16 A | 3 | 100% |  |  |  |  |  |  |  |  |
| 5 | 1.1.3 | Land allocation approval by authorities | manual | 30d | 2015-03-17 A | 2015-04-27 A | 4 | 100% |  |  |  |  |  |  |  |  |
| 6 | 1.1.4 | Obtaining of sanitary epidemiologic conclusion for land | manual | 7d | 2015-04-14 A | 2015-04-22 A | 4FS+20d | 100% |  |  |  |  |  |  |  |  |
| 7 | 1.1.5 | Radiological examination of land |  | 7d | 2015-04-14 A | 2015-04-22 A | 4FS+20d | 100% |  |  |  | Independent laboratory | 56h | 56h |  |  |
| 8 | 1.1.6 | Land committee decision | manual | 6d | 2015-04-28 A | 2015-05-05 A | 5, 7 | 100% |  |  |  |  |  |  |  |  |
| 9 | 1.2 | **Landcontrolling project** |  | 23d | 2015-04-23 A | 2015-05-25 |  | 30% | 16.1d | 0d |  |  |  |  | 3,632 | 1,271.2 |
| 10 | 1.2.1 | Making of Landcontrolling project | manual | 20d | 2015-04-23 A | 2015-05-20 | 5FS-5d, 8FS-12d | 35% | 13.1d |  | finish no earlier than 2015-05-20 |  |  |  | 3,632 | 1,271.2 |
| 11 | 1.2.2 | Approval of Project by authorities |  | 3d | 2015-05-21 | 2015-05-25 | 10 |  |  | 0d |  |  |  |  |  |  |
| 12 | 1.3 | **Land Permit& Land Lease** |  | 24d | 2015-05-26 | 2015-06-26 |  |  |  | 0d |  |  |  |  | 550 |  |
| 13 | 1.3.1 | Transmission of Landcontrolling project to district authority |  | 2d | 2015-05-26 | 2015-05-27 | 11 |  |  | 0d |  |  |  |  |  |  |
| 14 | 1.3.2 | Land Permit approval by district Head |  | 4d | 2015-05-28 | 2015-06-02 | 13 |  |  | 0d |  |  |  |  |  |  |
| 15 | 1.3.3 | Transmission of Landcontrolling project to region authority |  | 2d | 2015-06-03 | 2015-06-04 | 14 |  |  | 0d |  |  |  |  |  |  |
| 16 | 1.3.4 | Land Permit approval by region Head |  | 4d | 2015-06-05 | 2015-06-10 | 15 |  |  | 0d |  |  |  |  |  |  |
| 17 | 1.3.5 | Signing of Land lease agreement | manual | 5d | 2015-06-11 | 2015-06-17 | 16 |  |  |  |  |  |  |  | 300 |  |
| 18 | 1.3.6 | Obtaining of State Certificate to Land (Land Permit) |  | 7d | 2015-06-18 | 2015-06-26 | 17 |  |  | 0d |  |  |  |  | 250 |  |

Notes:
- 7: Independent laboratory
- 17: Land lease payment- app. $18 per 1ha per year. / $300 in our case.
