# WORK PROGRAM

Schedule from MS Project, 2013-11-01 to 2016-08-03, status date 2013-10-01, 24 hours a day, costs in $, A marks actual dates.
еткмкермнр

## Calendars

- 24 Hours: Mon-Sun 00:00-24:00.

## Schedule

| ID | WBS | Task | Type | Duration | Start | Finish | Predecessors | Complete | Remaining | Total slack | Free slack | Constraint | Cost | Actual cost | Ответственный | Text11 |
| --- | --- | --- | --- | --- | --- | --- | --- | --- | --- | --- | --- | --- | --- | --- | --- | --- |
| 1 | 1 | **Company Name** |  | 1006d | 2013-11-01 A | 2016-08-03 |  | 18% | 820.33d | 0d |  |  | 34,092,833 | 1,033,118.5 | Name |  |
| 2 | 1.1 | **2D seismic** |  | 158d | 2013-11-01 A | 2014-04-08 |  | 59% | 65.54d | 848d |  |  | 635,553 | 605,046.5 | Name |  |
| 3 | 1.1.1 | **2D seismic work** |  | 59d | 2013-11-01 A | 2013-12-30 A |  | 100% |  |  |  |  | 582,850 | 582,850 | Name |  |
| 4 | 1.1.1.1 | Technical project preparation |  | 15d | 2013-11-01 A | 2013-11-16 A |  | 100% |  |  |  | start no earlier than 2013-11-01 | 26,700 | 26,700 | Name | 3001 |
| 5 | 1.1.1.2 | Payment to 5 land holders | milestone | 0d | 2013-11-16 A | 2013-11-16 A | 4 | 100% |  |  |  |  | 33,000 | 33,000 | Name | 3001 |
| 6 | 1.1.1.3 | TP Approval |  | 10d | 2013-11-16 A | 2013-11-26 A | 5 | 100% |  |  |  |  |  |  | Name | 3001 |
| 7 | 1.1.1.4 | Mobilization |  | 20d | 2013-11-26 A | 2013-12-16 A | 6 | 100% |  |  |  |  | 166,300 | 166,300 | Name | 3001 |
| 8 | 1.1.1.5 | Stand by payment - 4 days due to geting permition |  | 4d | 2013-12-16 A | 2013-12-20 A | 7 | 100% |  |  |  |  | 30,000 | 30,000 | Name | 3001 |
| 9 | 1.1.1.6 | 2D seismic work |  | 12d | 2013-12-16 A | 2013-12-28 A | 8 | 100% |  |  |  |  | 183,950 | 183,950 | Name | 3001 |
| 10 | 1.1.1.7 | Demobilization |  | 1d | 2013-12-28 A | 2013-12-29 A | 9 | 100% |  |  |  |  | 142,900 | 142,900 | Name | 3001 |
| 11 | 1.1.1.8 | 2D seismic delivery |  | 2d | 2013-12-28 A | 2013-12-30 A | 9 | 100% |  |  |  |  |  |  | Name | 3001 |
| 12 | 1.1.2 | **2D Processing and Interpretation** |  | 98d | 2013-12-31 A | 2014-04-08 |  | 38% | 61.14d | 848d |  |  | 52,703 | 22,196.5 | Name |  |
| 13 | 1.1.2.1 | 2D seismic processing (time) - 57,5 km |  | 20d | 2013-12-31 A | 2014-01-20 A | 11 | 100% |  |  |  |  | 10,000 | 10,000 | Name | 3001 |
| 14 | 1.1.2.2 | 2D seismic processing (Dept) - - 57,5 km |  | 19d | 2014-01-10 A | 2014-01-29 A | 13FS-10d | 100% |  |  |  |  | 7,361 | 7,361 | Name | 3001 |
| 15 | 1.1.2.3 | 2D seismic interpretation (included 3D and log interpretation) |  | 14d | 2014-01-24 A | 2014-02-07 | 14FS-5d | 25% | 10.5d | 1.75d | 0d |  | 19,342 | 4,835.5 | Name | 3001 |
| 16 | 1.1.2.4 | Preparation and submission of the report to the MTD ZapKazNedra and RCGI |  | 60d | 2014-02-07 | 2014-04-08 | 15 |  |  | 848d |  |  | 16,000 |  | Name | 3001 |
| 17 | 1.1.3 | Correction of wells location | milestone | 0d | 2014-01-31 | 2014-01-31 | 15FS-7d |  |  | 1.75d | 0d |  |  |  | Name | 3001 |
| 18 | 1.1.4 | Approval well location |  | 5d | 2014-01-31 | 2014-02-05 | 17 |  |  | 910d |  |  |  |  | Name | 3001 |
| 19 | 1.2 | **Insurance** |  | 334d | 2014-02-01 A | 2015-01-01 |  | 80% | 66.8d | 580d |  |  | 395,000 | 316,000 | Name |  |
| 20 | 1.2.1 | Compulsory insurance of GPO of the employer for damnification of life and to health of the worker in case of execution of labor (office) obligations by it |  | 334d | 2014-02-01 A | 2014-12-31 |  | 80% | 66.8d | 580d |  | start no earlier than 2013-02-01 | 10,000 | 8,000 | Name | 1004 |
| 21 | 1.2.2 | Compulsory insurance of GPO of owners of the objects, which activities it is connected with danger of damnification to the third parties (insurance cover ~$30M) |  | 334d | 2014-02-01 A | 2015-01-01 |  | 80% | 66.8d | 580d |  | start no earlier than 2013-03-01 | 100,000 | 80,000 | Name | 4218 |
| 22 | 1.2.3 | Compulsory ecological insurance |  | 306d | 2014-02-28 A | 2014-12-31 |  | 80% | 61.2d | 581d |  | finish no earlier than 2013-12-31 | 10,000 | 8,000 | Name | 4218 |
| 23 | 1.2.4 | Risks insurance on the well (insurance cover ~$30M) |  | 306d | 2014-02-28 A | 2014-12-31 |  | 80% | 61.2d | 581d |  | finish no earlier than 2013-12-31 | 250,000 | 200,000 | Name | 4218 |
| 24 | 1.2.5 | Medical insurance of workers |  | 333d | 2014-02-01 A | 2014-12-31 |  | 80% | 66.6d | 581d |  | finish no earlier than 2013-12-31 | 25,000 | 20,000 | Name | 1004 |

Notes:
- 1: Text2: BOLZ
- 19: Text2: Insurance
- 20: Text2: Compulsory insurance of GPO of the employer for damnification of life and to health of the worker in case of execution of labor (office) obligations by it
- 21: Text2: Compulsory insurance of GPO of owners of the objects, which activities it is connected with danger of damnification to the third parties
- 22: Text2: Compulsory ecological insurance
- 23: Text2: risks insurance of an exit of a well from - under control
- 24: Text2: Medical insurance of workers

| ID | WBS | Task | Duration | Start | Finish | Predecessors | Complete | Remaining | Total slack | Free slack | Constraint | Cost | Actual cost | Ответственный | Text2 | Text11 |
| --- | --- | --- | --- | --- | --- | --- | --- | --- | --- | --- | --- | --- | --- | --- | --- | --- |
| 25 | 1.3 | **Construction** | 195d | 2013-12-12 A | 2014-06-25 |  | 16% | 164.65d | 770d |  |  | 1,678,800 | 42,000 | Name | Construction |  |
| 26 | 1.3.1 | **Design of well sites, access roads and wellholes** | 122d | 2013-12-12 A | 2014-04-13 |  | 34% | 81.08d | 843d |  |  | 93,800 | 42,000 | Name | Design of well sites, access roads and wellholes |  |
| 27 | 1.3.1.1 | Contract signing | 35d | 2013-12-12 A | 2014-01-16 |  | 97% | 1d | 930d |  | finish no earlier than 2014-01-14 |  |  | Name |  | 420107 |
| 28 | 1.3.1.2 | **Development of the project** | 45d | 2014-01-15 A | 2014-03-01 |  | 84% | 7.29d | 876d |  |  | 46,600 | 42,000 | Name |  |  |
| 29 | 1.3.1.2.1 | Topographic-geodetic surveys | 3d | 2014-01-15 A | 2014-01-18 A |  | 100% |  |  |  | start no earlier than 2014-01-15 | 10,000 | 10,000 | Name |  | 420107 |
| 30 | 1.3.1.2.2 | Geotechnical works | 45d | 2014-01-15 A | 2014-03-01 A |  | 100% |  |  |  | start no earlier than 2014-01-15 | 15,000 | 15,000 | Name |  | 420107 |
| 31 | 1.3.1.2.3 | Graphic part | 8d | 2014-01-20 A | 2014-01-28 A | 29 | 100% |  |  |  | start no earlier than 2014-01-20 | 10,000 | 10,000 | Name |  | 420107 |
| 32 | 1.3.1.2.4 | Estimate documentation | 5d | 2014-01-30 A | 2014-02-04 | 31 | 70% | 1.5d | 46d | 0d | start no earlier than 2014-01-30 | 10,000 | 7,000 | Name |  | 420107 |
| 33 | 1.3.1.2.5 | Explanatory note | 10d | 2014-01-24 | 2014-02-03 |  |  |  | 902d | 0d | start no earlier than 2014-01-24 | 1,600 |  | Name |  | 420107 |
| 34 | 1.3.1.3 | **Allocation of land plots** | 36d | 2014-01-31 A | 2014-03-08 |  | 3% | 34.97d | 879d |  |  | 43,000 |  | Name |  |  |
| 35 | 1.3.1.3.1 | Act of choice land | 5d | 2014-01-31 A | 2014-02-05 | 17 | 35% | 3.25d | 76d | 0d | start no earlier than 2014-01-23 |  |  | Name |  | 420107 |
| 36 | 1.3.1.3.2 | Conclusion Land Commission (14 signatures) | 5d | 2014-02-05 | 2014-02-10 | 35 |  |  | 76d | 0d | start no earlier than 2014-02-03 |  |  | Name |  | 420107 |
| 37 | 1.3.1.3.3 | The issue with land users (4 signatures) | 5d | 2014-02-05 | 2014-02-10 | 35 |  |  | 76d | 0d | start no earlier than 2014-01-23 | 30,000 |  | Name |  | 420105 |
| 38 | 1.3.1.3.4 | Land project - design | 20d | 2014-02-10 | 2014-03-02 | 37, 36 |  |  | 885d |  | start no earlier than 2014-02-03 | 6,500 |  | Name |  | 420107 |
| 39 | 1.3.1.3.5 | Land reclamation project | 20d | 2014-02-10 | 2014-03-02 | 37, 36 |  |  | 76d | 0d | start no earlier than 2014-02-04 | 6,500 |  | Name |  | 420105 |
| 40 | 1.3.1.3.6 | Decision of the head of region | 2d | 2014-03-02 | 2014-03-04 | 39 |  |  | 76d | 0d | start no earlier than 2014-03-02 |  |  | Name |  | 420107 |
| 41 | 1.3.1.3.7 | Resolution of the head of region | 2d | 2014-03-04 | 2014-03-06 | 40 |  |  | 76d | 0d | start no earlier than 2014-03-04 |  |  | Name |  | 420107 |
| 42 | 1.3.1.3.8 | Allocation of land plots | 2d | 2014-03-06 | 2014-03-08 | 41 |  |  | 76d | 4d | start no earlier than 2014-03-06 |  |  | Name |  | 420107 |
| 43 | 1.3.1.4 | Section HSE | 5d | 2014-02-04 | 2014-02-09 | 32 |  |  | 906d |  | start no earlier than 2014-02-04 | 1,600 |  | Name |  | 420107 |
| 44 | 1.3.1.5 | Conclusion on Industrial Safety Department | 10d | 2014-02-03 | 2014-02-13 | 33 |  |  | 902d |  | start no earlier than 2014-02-03 | 2,600 |  | Name |  | 420107 |
| 45 | 1.3.1.6 | **Approval from state authorities** | 30d | 2014-03-12 | 2014-04-11 |  |  |  | 845d |  |  |  |  | Name |  |  |
| 46 | 1.3.1.6.1 | Sanitary and epidemiological expertise | 10d | 2014-03-12 | 2014-03-22 | 42 |  |  | 865d |  | start no earlier than 2014-03-12 |  |  | Name |  | 420107 |
| 47 | 1.3.1.6.2 | Ecological Expertise | 30d | 2014-03-12 | 2014-04-11 | 42 |  |  | 845d |  | start no earlier than 2014-03-12 |  |  | Name |  | 420107 |
| 48 | 1.3.1.6.3 | Harmonization of of the project and the land reclamation project | 10d | 2014-03-12 | 2014-03-22 | 42 |  |  | 865d |  | start no earlier than 2014-03-12 |  |  | Name |  | 420107 |
| 49 | 1.3.1.6.4 | Receiving of project approval | 20d | 2014-03-12 | 2014-04-01 | 42 |  |  | 855d |  | start no earlier than 2014-03-12 |  |  | Name |  | 420107 |
| 50 | 1.3.1.7 | Conclusion of the State examination | 32d | 2014-03-12 | 2014-04-13 | 42 |  |  | 72d |  | start no earlier than 2014-03-12 |  |  | Name |  | 420107 |

Notes:
- 25: Инженер строитель

| ID | WBS | Task | Type | Duration | Start | Finish | Predecessors | Complete | Remaining | Total slack | Free slack | Constraint | Cost | Ответственный | Text2 | Text11 |
| --- | --- | --- | --- | --- | --- | --- | --- | --- | --- | --- | --- | --- | --- | --- | --- | --- |
| 51 | 1.3.2 | **Construction of drill site, wellholes and roads** |  | 125d | 2014-02-04 | 2014-06-09 |  |  |  | 20d |  |  | 1,550,000 | Name | Construction of drill site, wellholes and roads |  |
| 52 | 1.3.2.1 | Development of Technical Specification |  | 7d | 2014-02-04 | 2014-02-11 | 32 |  |  | 46d | 0d | start no earlier than 2013-09-20 |  | Name | Development of Technical Assignment | 4201 |
| 53 | 1.3.2.2 | Preparation of Bidding documentation |  | 3d | 2014-02-11 | 2014-02-14 | 52 |  |  | 46d | 0d |  |  | Name | Preparation of Bidding documentation | 4201 |
| 54 | 1.3.2.3 | Announcement in media | milestone | 0d | 2014-02-14 | 2014-02-14 | 53 |  |  | 46d | 0d | start no earlier than 2012-06-15 |  | Name | Announcement in media | 4201 |
| 55 | 1.3.2.4 | Preparation and submission of bidding application |  | 30d | 2014-02-14 | 2014-03-16 | 54 |  |  | 46d | 0d | finish no earlier than 2012-07-08 |  | Name | Preparation and submission of bidding application | 4201 |
| 56 | 1.3.2.5 | Evaluation and choosing the contractor |  | 1d | 2014-03-16 | 2014-03-17 | 55 |  |  | 46d | 0d | finish no earlier than 2012-07-15 |  | Name | Evaluation and choosing the contractor/supplier | 4201 |
| 57 | 1.3.2.6 | Request a quotation |  | 3d | 2014-03-17 | 2014-03-20 | 56 |  |  | 46d | 0d | finish no earlier than 2014-01-15 |  | Name |  | 4201 |
| 58 | 1.3.2.7 | Contract signing |  | 5d | 2014-03-20 | 2014-03-25 | 57 |  |  | 46d |  | finish no earlier than 2012-08-22 |  | Name | Contract signing with contractor/supplier | 4201 |
| 59 | 1.3.2.8 | **Construction of well sites, access road and wellhole** |  | 109d | 2014-02-20 | 2014-06-09 |  |  |  | 4d |  |  | 1,550,000 | Name | Construction of well sites, access road and wellhole |  |
| 60 | 1.3.2.8.1 | Materials delivery on site |  | 75d | 2014-02-20 | 2014-05-06 |  |  |  | 4d |  | start no earlier than 2014-02-20 |  | Name |  | 4201 |
| 61 | 1.3.2.8.2 | Road - 5km |  | 30d | 2014-05-10 | 2014-06-09 | 58, 60 |  |  | 0d |  | start no earlier than 2014-05-10 | 1,250,000 | Name |  | 4201 |
| 62 | 1.3.2.8.3 | Well area |  | 15d | 2014-05-10 | 2014-05-25 | 58, 60 |  |  | 15d |  | start no earlier than 2014-05-10 | 270,000 | Name |  | 4201 |
| 63 | 1.3.2.8.4 | Well hole and Drilling 0-20m, cementing D30", WOC |  | 15d | 2014-05-10 | 2014-05-25 | 58, 60 |  |  | 801d |  | start no earlier than 2014-05-10 | 30,000 | Name |  | 4201 |
| 64 | 1.3.3 | **Preliminary environmental audit** |  | 144d | 2014-02-01 | 2014-06-25 |  |  |  | 770d |  |  | 35,000 | Name |  |  |
| 65 | 1.3.3.1 | Development of Technical Specification |  | 5d | 2014-02-01 | 2014-02-06 |  |  |  | 770d | 0d | start no earlier than 2014-02-01 |  | Name |  | 43020406 |
| 66 | 1.3.3.2 | Preparation of Bidding documentation |  | 2d | 2014-02-06 | 2014-02-08 | 65 |  |  | 770d | 0d | finish no earlier than 2013-12-04 |  | Name |  | 43020406 |
| 67 | 1.3.3.3 | Announcement in media | milestone | 0d | 2014-02-08 | 2014-02-08 | 66 |  |  | 770d | 0d | finish no earlier than 2013-12-04 |  | Name |  | 43020406 |
| 68 | 1.3.3.4 | Preparation and submission of bidding application |  | 30d | 2014-02-08 | 2014-03-10 | 67 |  |  | 770d | 0d | finish no earlier than 2014-01-03 |  | Name |  | 43020406 |
| 69 | 1.3.3.5 | Evaluation and choosing the contractor |  | 7d | 2014-03-10 | 2014-03-17 | 68 |  |  | 770d | 0d | finish no earlier than 2014-01-10 |  | Name |  | 43020406 |
| 70 | 1.3.3.6 | Request a quotation |  | 3d | 2014-03-17 | 2014-03-20 | 69 |  |  | 770d | 0d | start no earlier than 2014-01-19 |  | Name |  | 43020406 |
| 71 | 1.3.3.7 | Contract signing |  | 7d | 2014-03-20 | 2014-03-27 | 70 |  |  | 770d | 0d | finish no earlier than 2014-01-20 |  | Name |  | 43020406 |
| 72 | 1.3.3.8 | Preliminary environmental audit |  | 60d | 2014-03-27 | 2014-05-26 | 71 |  |  | 770d | 0d |  | 35,000 | Name |  | 43020406 |
| 73 | 1.3.3.9 | Approval of PEA documents |  | 30d | 2014-05-26 | 2014-06-25 | 72 |  |  | 770d |  |  |  | Name |  | 43020406 |
| 74 | 1.4 | **Drilling of exploration well #1** |  | 975d | 2013-12-02 A | 2016-08-03 |  | 3% | 950.54d | 0d |  |  | 30,750,765 | Name | Drilling of exploration wells |  |
| 75 | 1.4.1 | **Tender procedures** |  | 225d | 2013-12-02 A | 2014-07-15 |  | 10% | 202.38d | 750d |  |  |  | Name | Tender procedures |  |
| 76 | 1.4.1.1 | **Drilling rig** |  | 21d | 2014-01-27 A | 2014-02-17 |  |  | 21d | 898d |  |  |  | Name | Drilling rig |  |
| 77 | 1.4.1.1.1 | Development of Technical Specification | milestone | 0d | 2014-01-27 A | 2014-01-27 A |  | 100% |  |  |  | start no earlier than 2013-11-26 |  | Name | Development of Technical Assignment | 420202 |
| 78 | 1.4.1.1.2 | Preparation of Bidding documentation | milestone | 0d | 2014-01-27 A | 2014-01-27 A | 77 | 100% |  |  |  | finish no earlier than 2013-10-16 |  | Name | Preparation of Bidding documentation | 420202 |
| 79 | 1.4.1.1.3 | Announcement in media | milestone | 0d | 2014-01-27 A | 2014-01-27 A | 78 | 100% |  |  |  | start no earlier than 2012-05-25 |  | Name | Announcement in media | 420202 |
| 80 | 1.4.1.1.4 | Preparation and submission of bidding application |  | 15d | 2014-01-27 | 2014-02-11 | 79 |  |  | 898d | 0d | finish no earlier than 2013-11-15 |  | Name | Preparation and submission of bidding application | 420202 |
| 81 | 1.4.1.1.5 | Evaluation and choosing the contractor |  | 1d | 2014-02-11 | 2014-02-12 | 80 |  |  | 898d | 0d | finish no earlier than 2014-01-24 |  | Name | Evaluation and choosing the contractor/supplier | 420202 |
| 82 | 1.4.1.1.6 | Request a quotation |  | 2d | 2014-02-12 | 2014-02-14 | 81 |  |  | 898d | 0d | start no earlier than 2013-12-31 |  | Name |  | 420202 |
| 83 | 1.4.1.1.7 | Approve by tender board |  | 2d | 2014-02-14 | 2014-02-16 | 82 |  |  | 898d | 0d |  |  | Name |  | 420202 |
| 84 | 1.4.1.1.8 | Contract signing |  | 1d | 2014-02-16 | 2014-02-17 | 83 |  |  | 898d |  | start no earlier than 2014-02-15 |  | Name | Contract signing with contractor/supplier | 420202 |

Notes:
- 62: Text10: Direct contract with contractor due to risk of delay of drilling operation - in winter time bed env condition for heavy equipment to truck it
- 63: Text10: The drilling rig will be mob to the site by winter, frozen road. This scop of work will be included in tender. Risk - $280k

| ID | WBS | Task | Type | Duration | Start | Finish | Predecessors | Complete | Remaining | Total slack | Free slack | Constraint | Ответственный | Text2 | Text11 |
| --- | --- | --- | --- | --- | --- | --- | --- | --- | --- | --- | --- | --- | --- | --- | --- |
| 85 | 1.4.1.2 | **Casing, tubing, Lubricants and Tooling casing** |  | 79d | 2013-12-20 A | 2014-03-09 |  | 12% | 69.78d | 53d |  |  | Name | Lubricants for casing string purchasing |  |
| 86 | 1.4.1.2.1 | Development of Technical Specification |  | 5d | 2013-12-20 A | 2013-12-25 A |  | 100% |  |  |  | start no earlier than 2013-10-01 | Name | Development of Technical Assignment | 4220 |
| 87 | 1.4.1.2.2 | Preparation of Bidding documentation |  | 2d | 2013-12-25 A | 2013-12-27 A | 86 | 100% |  |  |  | finish no earlier than 2013-10-09 | Name | Preparation of Bidding documentation | 4220 |
| 88 | 1.4.1.2.3 | Announcement in media |  | 6d | 2014-01-15 A | 2014-01-21 | 87 |  | 6d | 53d | 0d | start no earlier than 2014-01-15 | Name | Announcement in media | 4220 |
| 89 | 1.4.1.2.4 | Preparation and submission of bidding application |  | 30d | 2014-01-21 | 2014-02-20 | 88 |  |  | 53d | 0d | finish no earlier than 2012-08-21 | Name | Preparation and submission of bidding application | 4220 |
| 90 | 1.4.1.2.5 | Evaluation and choosing the supplier |  | 7d | 2014-02-20 | 2014-02-27 | 89 |  |  | 53d | 0d | finish no earlier than 2013-11-16 | Name | Evaluation and choosing the contractor/supplier | 4220 |
| 91 | 1.4.1.2.6 | Request a quotation |  | 3d | 2014-02-27 | 2014-03-02 | 90 |  |  | 53d | 0d |  | Name |  | 4220 |
| 92 | 1.4.1.2.7 | Approve by tender board |  | 2d | 2014-03-02 | 2014-03-04 | 91 |  |  | 53d | 0d |  | Name |  | 4220 |
| 93 | 1.4.1.2.8 | Contract signing |  | 5d | 2014-03-04 | 2014-03-09 | 92 |  |  | 53d | 0d | finish no earlier than 2012-08-28 | Name | Contract signing with contractor/supplier | 4220 |
| 94 | 1.4.1.3 | **Casing head and X-mas tree** |  | 62d | 2014-01-03 A | 2014-03-06 |  | 13% | 54.11d | 791d |  |  | Name | Well-head equipment, casing head and X-mas tree |  |
| 95 | 1.4.1.3.1 | Development of Technical Specification |  | 5d | 2014-01-03 A | 2014-01-08 A |  | 100% |  |  |  | start no earlier than 2013-10-01 | Name | Development of Technical Assignment | 422301 |
| 96 | 1.4.1.3.2 | Preparation of Bidding documentation |  | 2d | 2014-01-08 A | 2014-01-10 A | 95 | 100% |  |  |  | start no earlier than 2013-10-04 | Name | Preparation of Bidding documentation | 422301 |
| 97 | 1.4.1.3.3 | Announcement in media |  | 3d | 2014-01-17 | 2014-01-20 | 96 |  |  | 791d | 0d | start no earlier than 2014-01-17 | Name | Announcement in media | 422301 |
| 98 | 1.4.1.3.4 | Preparation and submission of bidding application |  | 30d | 2014-01-20 | 2014-02-19 | 97 |  |  | 791d | 0d | start no earlier than 2013-10-08 | Name | Preparation and submission of bidding application | 422301 |
| 99 | 1.4.1.3.5 | Evaluation and choosing the supplier |  | 5d | 2014-02-19 | 2014-02-24 | 98 |  |  | 791d | 0d | start no earlier than 2013-11-07 | Name | Evaluation and choosing the contractor/supplier | 422301 |
| 100 | 1.4.1.3.6 | Request a quotation |  | 3d | 2014-02-24 | 2014-02-27 | 99 |  |  | 791d | 0d | finish no earlier than 2014-01-29 | Name |  | 422301 |
| 101 | 1.4.1.3.7 | Approve by tender board |  | 2d | 2014-02-27 | 2014-03-01 | 100 |  |  | 791d | 0d |  | Name |  | 422301 |
| 102 | 1.4.1.3.8 | Contract signing |  | 5d | 2014-03-01 | 2014-03-06 | 101 |  |  | 791d | 0d | start no earlier than 2013-11-14 | Name | Contract signing with contractor/supplier | 422301 |
| 103 | 1.4.1.4 | **Drilling bits** |  | 70d | 2014-01-10 A | 2014-03-20 |  | 5% | 66.55d | 776d |  |  | Name | Drilling bits |  |
| 104 | 1.4.1.4.1 | Development of Technical Specification |  | 23d | 2014-01-10 A | 2014-02-01 | 96 | 15% | 19.55d | 776d | 0d | finish no earlier than 2014-02-01 | Name | Development of Technical Assignment | 420801 |
| 105 | 1.4.1.4.2 | Preparation of Bidding documentation |  | 2d | 2014-02-01 | 2014-02-03 | 104 |  |  | 776d | 0d | finish no earlier than 2013-10-20 | Name | Preparation of Bidding documentation | 420801 |
| 106 | 1.4.1.4.3 | Announcement in media | milestone | 0d | 2014-02-03 | 2014-02-03 | 105 |  |  | 776d | 0d | finish no earlier than 2013-10-20 | Name | Announcement in media | 420801 |
| 107 | 1.4.1.4.4 | Preparation and submission of bidding application |  | 30d | 2014-02-03 | 2014-03-05 | 106 |  |  | 776d | 0d | finish no earlier than 2013-11-19 | Name | Preparation and submission of bidding application | 420801 |
| 108 | 1.4.1.4.5 | Evaluation and choosing the supplier |  | 5d | 2014-03-05 | 2014-03-10 | 107 |  |  | 776d | 0d | finish no earlier than 2013-11-28 | Name | Evaluation and choosing the contractor/supplier | 420801 |
| 109 | 1.4.1.4.6 | Request a quotation |  | 3d | 2014-03-10 | 2014-03-13 | 108 |  |  | 776d | 0d | finish no earlier than 2014-01-29 | Name |  | 420801 |
| 110 | 1.4.1.4.7 | Approve by tender board |  | 2d | 2014-03-13 | 2014-03-15 | 109 |  |  | 776d | 0d |  | Name |  | 420801 |
| 111 | 1.4.1.4.8 | Contract signing |  | 5d | 2014-03-15 | 2014-03-20 | 110 |  |  | 776d | 0d | finish no earlier than 2013-12-10 | Name | Contract signing with contractor/supplier | 420801 |

| ID | WBS | Task | Type | Duration | Start | Finish | Predecessors | Complete | Remaining | Total slack | Free slack | Constraint | Ответственный | Text2 | Text11 |
| --- | --- | --- | --- | --- | --- | --- | --- | --- | --- | --- | --- | --- | --- | --- | --- |
| 112 | 1.4.1.5 | **Mud services, chemicals, engineering** |  | 65d | 2014-01-08 A | 2014-03-13 |  | 7% | 60.5d | 873d |  |  | Name | Mud services, chemicals, engineering |  |
| 113 | 1.4.1.5.1 | Development of Technical Specification |  | 18d | 2014-01-08 A | 2014-01-25 |  | 25% | 13.5d | 873d | 0d | finish no earlier than 2014-01-25 | Name | Development of Technical Assignment | 420901 |
| 114 | 1.4.1.5.2 | Preparation of Bidding documentation |  | 2d | 2014-01-25 | 2014-01-27 | 113 |  |  | 873d | 0d | finish no earlier than 2013-10-20 | Name | Preparation of Bidding documentation | 420901 |
| 115 | 1.4.1.5.3 | Announcement in media | milestone | 0d | 2014-01-27 | 2014-01-27 | 114 |  |  | 873d | 0d | start no earlier than 2013-10-20 | Name | Announcement in media | 420901 |
| 116 | 1.4.1.5.4 | Preparation and submission of bidding application |  | 30d | 2014-01-27 | 2014-02-26 | 115 |  |  | 873d | 0d | start no earlier than 2013-10-20 | Name | Preparation and submission of bidding application | 420901 |
| 117 | 1.4.1.5.5 | Evaluation and choosing the contractor |  | 5d | 2014-02-26 | 2014-03-03 | 116 |  |  | 873d | 0d | start no earlier than 2013-11-19 | Name | Evaluation and choosing the contractor/supplier | 420901 |
| 118 | 1.4.1.5.6 | Request a quotation |  | 3d | 2014-03-03 | 2014-03-06 | 117 |  |  | 873d | 0d | finish no earlier than 2014-02-05 | Name |  | 420901 |
| 119 | 1.4.1.5.7 | Approve by tender board |  | 2d | 2014-03-06 | 2014-03-08 | 118 |  |  | 873d | 0d |  | Name |  | 420901 |
| 120 | 1.4.1.5.8 | Contract signing |  | 5d | 2014-03-08 | 2014-03-13 | 119 |  |  | 873d |  | start no earlier than 2013-11-28 | Name | Contract signing with contractor/supplier | 420901 |
| 121 | 1.4.1.6 | **Cementing services** |  | 61d | 2014-01-20 | 2014-03-22 |  |  |  | 720d |  |  | Name | Cementing services |  |
| 122 | 1.4.1.6.1 | Development of Technical Specification |  | 15d | 2014-01-20 | 2014-02-04 |  |  |  | 720d | 0d | start no earlier than 2014-01-20 | Name | Development of Technical Assignment | 4207 |
| 123 | 1.4.1.6.2 | Preparation of Bidding documentation |  | 1d | 2014-02-04 | 2014-02-05 | 122 |  |  | 720d | 0d | finish no earlier than 2013-10-20 | Name | Preparation of Bidding documentation | 4207 |
| 124 | 1.4.1.6.3 | Announcement in media | milestone | 0d | 2014-02-05 | 2014-02-05 | 123 |  |  | 720d | 0d | finish no earlier than 2013-10-20 | Name | Announcement in media | 4207 |
| 125 | 1.4.1.6.4 | Preparation and submission of bidding application |  | 30d | 2014-02-05 | 2014-03-07 | 124 |  |  | 720d | 0d | finish no earlier than 2013-11-19 | Name | Preparation and submission of bidding application | 4207 |
| 126 | 1.4.1.6.5 | Evaluation and choosing the contractor |  | 5d | 2014-03-07 | 2014-03-12 | 125 |  |  | 720d | 0d | finish no earlier than 2013-11-28 | Name | Evaluation and choosing the contractor/supplier | 4207 |
| 127 | 1.4.1.6.6 | Request a quotation |  | 3d | 2014-03-12 | 2014-03-15 | 126 |  |  | 720d | 0d | start no earlier than 2014-01-10 | Name |  | 4207 |
| 128 | 1.4.1.6.7 | Approve by tender board |  | 2d | 2014-03-15 | 2014-03-17 | 127 |  |  | 720d | 0d |  | Name |  | 4207 |
| 129 | 1.4.1.6.8 | Contract signing |  | 5d | 2014-03-17 | 2014-03-22 | 128 |  |  | 720d | 96d | finish no earlier than 2013-12-10 | Name | Contract signing with contractor/supplier | 4207 |
| 130 | 1.4.1.7 | **Bottom hole assemblies** |  | 61d | 2014-01-20 | 2014-03-22 |  |  |  | 720d |  |  | Name |  |  |
| 131 | 1.4.1.7.1 | Development of Technical Specification |  | 14d | 2014-01-20 | 2014-02-03 |  |  |  | 720d | 0d | start no earlier than 2014-01-20 | Name |  | 4210 |
| 132 | 1.4.1.7.2 | Preparation of Bidding documentation |  | 2d | 2014-02-03 | 2014-02-05 | 131 |  |  | 720d | 0d |  | Name |  | 4210 |
| 133 | 1.4.1.7.3 | Announcement in media | milestone | 0d | 2014-02-05 | 2014-02-05 | 132 |  |  | 720d | 0d |  | Name |  | 4210 |
| 134 | 1.4.1.7.4 | Preparation and submission of bidding application |  | 30d | 2014-02-05 | 2014-03-07 | 133 |  |  | 720d | 0d |  | Name |  | 4210 |
| 135 | 1.4.1.7.5 | Evaluation and choosing the supplier |  | 5d | 2014-03-07 | 2014-03-12 | 134 |  |  | 720d | 0d |  | Name |  | 4210 |
| 136 | 1.4.1.7.6 | Request a quotation |  | 3d | 2014-03-12 | 2014-03-15 | 135 |  |  | 720d | 0d | finish no earlier than 2014-02-19 | Name |  | 4210 |
| 137 | 1.4.1.7.7 | Approve by tender board |  | 2d | 2014-03-15 | 2014-03-17 | 136 |  |  | 720d | 0d |  | Name |  | 4210 |
| 138 | 1.4.1.7.8 | Contract signing |  | 5d | 2014-03-17 | 2014-03-22 | 137 |  |  | 720d | 96d |  | Name |  | 4210 |

| ID | WBS | Task | Type | Duration | Start | Finish | Predecessors | Complete | Remaining | Total slack | Free slack | Constraint | Ответственный | Text11 | Text2 |
| --- | --- | --- | --- | --- | --- | --- | --- | --- | --- | --- | --- | --- | --- | --- | --- |
| 139 | 1.4.1.8 | **Services of casing running** |  | 62d | 2014-01-08 | 2014-03-11 |  |  |  | 730d |  |  | Name |  |  |
| 140 | 1.4.1.8.1 | Development of Technical Specification |  | 15d | 2014-01-08 | 2014-01-23 |  |  |  | 730d | 0d | finish no earlier than 2014-01-23 | Name | 420601 |  |
| 141 | 1.4.1.8.2 | Preparation of Bidding documentation |  | 2d | 2014-01-23 | 2014-01-25 | 140 |  |  | 730d | 0d | finish no earlier than 2014-01-25 | Name | 420601 |  |
| 142 | 1.4.1.8.3 | Announcement in media | milestone | 0d | 2014-01-25 | 2014-01-25 | 141 |  |  | 730d | 0d | finish no earlier than 2014-01-25 | Name | 420601 |  |
| 143 | 1.4.1.8.4 | Preparation and submission of bidding application |  | 30d | 2014-01-25 | 2014-02-24 | 142 |  |  | 730d | 0d | finish no earlier than 2014-02-14 | Name | 420601 |  |
| 144 | 1.4.1.8.5 | Evaluation and choosing the contractor |  | 5d | 2014-02-24 | 2014-03-01 | 143 |  |  | 730d | 0d | finish no earlier than 2014-02-21 | Name | 420601 |  |
| 145 | 1.4.1.8.6 | Request a quotation |  | 3d | 2014-03-01 | 2014-03-04 | 144 |  |  | 730d | 0d | finish no earlier than 2014-02-24 | Name | 420601 |  |
| 146 | 1.4.1.8.7 | Approve by tender board |  | 2d | 2014-03-04 | 2014-03-06 | 145 |  |  | 730d | 0d |  | Name | 420601 |  |
| 147 | 1.4.1.8.8 | Contract signing |  | 5d | 2014-03-06 | 2014-03-11 | 146 |  |  | 730d | 106d | finish no earlier than 2014-03-03 | Name | 420601 |  |
| 148 | 1.4.1.9 | **Special transport (PikUp, Water truk, Buldoser, Crane, Excavator etc)** |  | 57d | 2014-01-20 A | 2014-03-18 |  | 2% | 56d | 684d |  |  | Name |  |  |
| 149 | 1.4.1.9.1 | Development of Technical Specification |  | 10d | 2014-01-20 A | 2014-01-30 |  | 10% | 9d | 684d | 0d | start no earlier than 2014-01-20 | Name | 4214 |  |
| 150 | 1.4.1.9.2 | Preparation of Bidding documentation |  | 2d | 2014-01-30 | 2014-02-01 | 149 |  |  | 684d | 0d | finish no earlier than 2014-01-25 | Name | 4214 |  |
| 151 | 1.4.1.9.3 | Announcement in media | milestone | 0d | 2014-02-01 | 2014-02-01 | 150 |  |  | 684d | 0d | finish no earlier than 2014-01-25 | Name | 4214 |  |
| 152 | 1.4.1.9.4 | Preparation and submission of bidding application |  | 30d | 2014-02-01 | 2014-03-03 | 151 |  |  | 684d | 0d | finish no earlier than 2014-02-14 | Name | 4214 |  |
| 153 | 1.4.1.9.5 | Evaluation and choosing the contractor |  | 5d | 2014-03-03 | 2014-03-08 | 152 |  |  | 684d | 0d | finish no earlier than 2014-02-21 | Name | 4214 |  |
| 154 | 1.4.1.9.6 | Request a quotation |  | 3d | 2014-03-08 | 2014-03-11 | 153 |  |  | 684d | 0d | finish no earlier than 2014-02-24 | Name | 4214 |  |
| 155 | 1.4.1.9.7 | Approve by tender board |  | 2d | 2014-03-11 | 2014-03-13 | 154 |  |  | 684d | 0d |  | Name | 4214 |  |
| 156 | 1.4.1.9.8 | Contract signing |  | 5d | 2014-03-13 | 2014-03-18 | 155 |  |  | 684d | 100d | finish no earlier than 2014-03-03 | Name | 4214 |  |
| 157 | 1.4.1.10 | **Logging, RCA, CBL, Perforation, Bridge Plug, RPN, HDT, GIS, Swabbing** |  | 90d | 2013-12-02 A | 2014-03-02 |  | 64% | 32.05d | 700d |  |  | Name |  | Logging |
| 158 | 1.4.1.10.1 | Development of Technical Specification |  | 15d | 2013-12-02 A | 2013-12-17 A |  | 100% |  |  |  | start no earlier than 2013-12-02 | Name | 420501 | Development of Technical Assignment |
| 159 | 1.4.1.10.2 | Preparation of Bidding documentation |  | 8d | 2013-12-17 A | 2013-12-25 A | 158 | 100% |  |  |  | finish no earlier than 2013-10-20 | Name | 420501 | Preparation of Bidding documentation |
| 160 | 1.4.1.10.3 | Announcement in media | milestone | 0d | 2014-01-09 A | 2014-01-09 A | 159 | 100% |  |  |  | finish no earlier than 2013-10-20 | Name | 420501 | Announcement in media |
| 161 | 1.4.1.10.4 | Preparation and submission of bidding application |  | 30d | 2014-01-09 A | 2014-02-08 | 160 | 80% | 6d | 702d | 2d | finish no earlier than 2013-11-19 | Name | 420501 | Preparation and submission of bidding application |
| 162 | 1.4.1.10.5 | Evaluation and choosing the contractor |  | 5d | 2014-02-10 | 2014-02-15 | 161 |  |  | 700d | 0d | start no earlier than 2014-02-10 | Name | 420501 | Evaluation and choosing the contractor/supplier |
| 163 | 1.4.1.10.6 | Request a quotation |  | 3d | 2014-02-15 | 2014-02-18 | 162 |  |  | 700d | 0d | start no earlier than 2014-01-19 | Name | 420501 |  |
| 164 | 1.4.1.10.7 | Approve by tender board |  | 2d | 2014-02-18 | 2014-02-20 | 163 |  |  | 700d | 0d |  | Name | 420501 |  |
| 165 | 1.4.1.10.8 | Contract signing |  | 10d | 2014-02-20 | 2014-03-02 | 164 |  |  | 700d | 116d | finish no earlier than 2013-12-10 | Name | 420501 | Contract signing with contractor/supplier |

| ID | WBS | Task | Type | Duration | Start | Finish | Predecessors | Complete | Remaining | Total slack | Free slack | Constraint | Ответственный | Text11 | Text2 |
| --- | --- | --- | --- | --- | --- | --- | --- | --- | --- | --- | --- | --- | --- | --- | --- |
| 166 | 1.4.1.11 | **Coring** |  | 84d | 2014-04-01 | 2014-06-24 |  |  |  | 3d |  |  | Name |  |  |
| 167 | 1.4.1.11.1 | Development of Technical Specification |  | 30d | 2014-04-01 | 2014-05-01 |  |  |  | 3d | 0d | start no earlier than 2014-04-01 | Name | 420504 |  |
| 168 | 1.4.1.11.2 | Preparation of Bidding documentation |  | 5d | 2014-05-01 | 2014-05-06 | 167 |  |  | 771d | 0d | start no earlier than 2014-01-09 | Name | 420504 |  |
| 169 | 1.4.1.11.3 | Announcement in media | milestone | 0d | 2014-05-06 | 2014-05-06 | 168 |  |  | 771d | 0d | start no earlier than 2014-01-14 | Name | 420504 |  |
| 170 | 1.4.1.11.4 | Preparation and submission of bidding application |  | 30d | 2014-05-06 | 2014-06-05 | 169 |  |  | 771d | 0d | start no earlier than 2014-01-14 | Name | 420504 |  |
| 171 | 1.4.1.11.5 | Evaluation and choosing the contractor |  | 7d | 2014-06-05 | 2014-06-12 | 170 |  |  | 771d | 0d | start no earlier than 2014-02-13 | Name | 420504 |  |
| 172 | 1.4.1.11.6 | Request a quotation |  | 3d | 2014-06-12 | 2014-06-15 | 171 |  |  | 771d | 0d | start no earlier than 2014-02-20 | Name | 420504 |  |
| 173 | 1.4.1.11.7 | Approve by tender board |  | 2d | 2014-06-15 | 2014-06-17 | 172 |  |  | 771d | 0d |  | Name | 420504 |  |
| 174 | 1.4.1.11.8 | Contract signing |  | 7d | 2014-06-17 | 2014-06-24 | 173 |  |  | 771d |  | start no earlier than 2014-02-23 | Name | 420504 |  |
| 175 | 1.4.1.12 | **Mud logging, VSP** |  | 83d | 2013-12-17 A | 2014-03-09 |  | 34% | 54.8d | 732d |  |  | Name |  | Mud logging |
| 176 | 1.4.1.12.1 | Development of Technical Specification |  | 3d | 2013-12-17 A | 2013-12-20 A | 158 | 100% |  |  |  | finish no earlier than 2013-10-12 | Name | 420503 | Development of Technical Assignment |
| 177 | 1.4.1.12.2 | Preparation of Bidding documentation |  | 28d | 2013-12-20 A | 2014-01-16 | 176 | 90% | 2.8d | 732d | 0d | finish no earlier than 2014-01-16 | Name | 420503 | Preparation of Bidding documentation |
| 178 | 1.4.1.12.3 | Announcement in media |  | 2d | 2014-01-16 | 2014-01-18 | 177 |  |  | 732d | 0d | finish no earlier than 2013-10-20 | Name | 420503 | Announcement in media |
| 179 | 1.4.1.12.4 | Preparation and submission of bidding application |  | 30d | 2014-01-18 | 2014-02-17 | 178 |  |  | 732d | 0d | finish no earlier than 2013-11-19 | Name | 420503 | Preparation and submission of bidding application |
| 180 | 1.4.1.12.5 | Evaluation and choosing the contractor |  | 5d | 2014-02-17 | 2014-02-22 | 179 |  |  | 732d | 0d | finish no earlier than 2013-11-28 | Name | 420503 | Evaluation and choosing the contractor/supplier |
| 181 | 1.4.1.12.6 | Request a quotation |  | 3d | 2014-02-22 | 2014-02-25 | 180 |  |  | 732d | 0d | start no earlier than 2014-02-14 | Name | 420503 |  |
| 182 | 1.4.1.12.7 | Approve by tender board |  | 2d | 2014-02-25 | 2014-02-27 | 181 |  |  | 732d | 0d |  | Name | 420503 |  |
| 183 | 1.4.1.12.8 | Contract signing |  | 10d | 2014-02-27 | 2014-03-09 | 182 |  |  | 732d | 108d | finish no earlier than 2013-12-10 | Name | 420503 | Contract signing with contractor/supplier |
| 184 | 1.4.1.13 | **Core analysis, Oil and Gas analysis** |  | 69d | 2014-01-02 A | 2014-03-12 |  | 24% | 52.5d | 784d |  |  | Name |  |  |
| 185 | 1.4.1.13.1 | Development of Technical Specification |  | 15d | 2014-01-02 A | 2014-01-17 A | 176 | 100% |  |  |  | finish no earlier than 2014-01-17 | Name | 420504 |  |
| 186 | 1.4.1.13.2 | Preparation of Bidding documentation |  | 5d | 2014-01-17 A | 2014-01-22 | 185 | 30% | 3.5d | 784d | 0d | start no earlier than 2014-01-09 | Name | 420504 |  |
| 187 | 1.4.1.13.3 | Announcement in media | milestone | 0d | 2014-01-22 | 2014-01-22 | 186 |  |  | 784d | 0d | start no earlier than 2014-01-14 | Name | 420504 |  |
| 188 | 1.4.1.13.4 | Preparation and submission of bidding application |  | 30d | 2014-01-22 | 2014-02-21 | 187 |  |  | 784d | 0d | start no earlier than 2014-01-14 | Name | 420504 |  |
| 189 | 1.4.1.13.5 | Evaluation and choosing the contractor |  | 7d | 2014-02-21 | 2014-02-28 | 188 |  |  | 784d | 0d | start no earlier than 2014-02-13 | Name | 420504 |  |
| 190 | 1.4.1.13.6 | Request a quotation |  | 3d | 2014-02-28 | 2014-03-03 | 189 |  |  | 784d | 0d | start no earlier than 2014-02-20 | Name | 420504 |  |
| 191 | 1.4.1.13.7 | Approve by tender board |  | 2d | 2014-03-03 | 2014-03-05 | 190 |  |  | 784d | 0d |  | Name | 420504 |  |
| 192 | 1.4.1.13.8 | Contract signing |  | 7d | 2014-03-05 | 2014-03-12 | 191 |  |  | 784d | 229d | start no earlier than 2014-02-23 | Name | 420504 |  |
| 193 | 1.4.1.14 | Core box buying |  | 30d | 2014-05-01 | 2014-05-31 |  |  |  | 765d | 0d | start no earlier than 2014-05-01 | Name | 420504 |  |

| ID | WBS | Task | Type | Duration | Start | Finish | Predecessors | Complete | Remaining | Total slack | Free slack | Constraint | Ответственный | Text11 | Text2 |
| --- | --- | --- | --- | --- | --- | --- | --- | --- | --- | --- | --- | --- | --- | --- | --- |
| 194 | 1.4.1.15 | **Acid treatment** |  | 70d | 2014-05-01 A | 2014-07-10 |  | 4% | 67d | 688d |  |  | Name |  |  |
| 195 | 1.4.1.15.1 | Development of Technical Specification |  | 15d | 2014-05-01 A | 2014-05-16 | 167 | 20% | 12d | 26d | 0d | start no earlier than 2014-01-11 | Name | 421501 |  |
| 196 | 1.4.1.15.2 | Preparation of Bidding documentation |  | 8d | 2014-05-16 | 2014-05-24 | 195 |  |  | 688d | 0d | finish no earlier than 2014-01-30 | Name | 421501 |  |
| 197 | 1.4.1.15.3 | Announcement in media | milestone | 0d | 2014-05-24 | 2014-05-24 | 196 |  |  | 688d | 0d | finish no earlier than 2014-01-30 | Name | 421501 |  |
| 198 | 1.4.1.15.4 | Preparation and submission of bidding application |  | 30d | 2014-05-24 | 2014-06-23 | 197 |  |  | 688d | 0d | finish no earlier than 2014-03-01 | Name | 421501 |  |
| 199 | 1.4.1.15.5 | Evaluation and choosing the contractor |  | 5d | 2014-06-23 | 2014-06-28 | 198 |  |  | 688d | 0d | finish no earlier than 2014-03-10 | Name | 421501 |  |
| 200 | 1.4.1.15.6 | Request a quotation |  | 3d | 2014-06-28 | 2014-07-01 | 199 |  |  | 688d | 0d | finish no earlier than 2014-03-13 | Name | 421501 |  |
| 201 | 1.4.1.15.7 | Approve by tender board |  | 2d | 2014-07-01 | 2014-07-03 | 200 |  |  | 688d | 0d |  | Name | 421501 |  |
| 202 | 1.4.1.15.8 | Contract signing |  | 7d | 2014-07-03 | 2014-07-10 | 201 |  |  | 688d | 131d | finish no earlier than 2014-03-22 | Name | 421501 |  |
| 203 | 1.4.1.16 | **Equipment for Well Testing** |  | 60d | 2014-05-16 | 2014-07-15 |  |  |  | 26d |  |  | Name |  |  |
| 204 | 1.4.1.16.1 | Development of Technical Specification |  | 11d | 2014-05-16 | 2014-05-27 | 195 |  |  | 26d | 0d | start no earlier than 2014-02-01 | Name | 430301 |  |
| 205 | 1.4.1.16.2 | Preparation of Bidding documentation |  | 2d | 2014-05-27 | 2014-05-29 | 204 |  |  | 720d | 0d | finish no earlier than 2014-01-30 | Name | 430301 |  |
| 206 | 1.4.1.16.3 | Announcement in media | milestone | 0d | 2014-05-29 | 2014-05-29 | 205 |  |  | 720d | 0d | finish no earlier than 2014-01-30 | Name | 430301 |  |
| 207 | 1.4.1.16.4 | Preparation and submission of bidding application |  | 30d | 2014-05-29 | 2014-06-28 | 206 |  |  | 720d | 0d | finish no earlier than 2014-03-01 | Name | 430301 |  |
| 208 | 1.4.1.16.5 | Evaluation and choosing the contractor |  | 5d | 2014-06-28 | 2014-07-03 | 207 |  |  | 720d | 0d | finish no earlier than 2014-03-10 | Name | 430301 |  |
| 209 | 1.4.1.16.6 | Request a quotation |  | 3d | 2014-07-03 | 2014-07-06 | 208 |  |  | 720d | 0d | finish no earlier than 2014-03-13 | Name | 430301 |  |
| 210 | 1.4.1.16.7 | Approve by tender board |  | 2d | 2014-07-06 | 2014-07-08 | 209 |  |  | 720d | 0d |  | Name | 430301 |  |
| 211 | 1.4.1.16.8 | Contract signing |  | 7d | 2014-07-08 | 2014-07-15 | 210 |  |  | 720d | 157d | finish no earlier than 2014-03-22 | Name | 430301 |  |
| 212 | 1.4.1.17 | **Technical water and fuel** |  | 64d | 2014-01-20 A | 2014-03-25 |  | 2% | 62.5d | 677d |  |  | Name |  | Technical water and fuel |
| 213 | 1.4.1.17.1 | Development of Technical Specification |  | 15d | 2014-01-20 A | 2014-02-04 |  | 10% | 13.5d | 677d | 0d | start no earlier than 2014-01-20 | Name | 4204 | Development of Technical Assignment |
| 214 | 1.4.1.17.2 | Preparation of Bidding documentation |  | 2d | 2014-02-04 | 2014-02-06 | 213 |  |  | 677d | 0d | finish no earlier than 2013-10-20 | Name | 4204 | Preparation of Bidding documentation |
| 215 | 1.4.1.17.3 | Announcement in media | milestone | 0d | 2014-02-06 | 2014-02-06 | 214 |  |  | 677d | 0d | finish no earlier than 2013-10-20 | Name | 4204 | Announcement in media |
| 216 | 1.4.1.17.4 | Preparation and submission of bidding application |  | 30d | 2014-02-06 | 2014-03-08 | 215 |  |  | 677d | 0d | finish no earlier than 2013-11-19 | Name | 4204 | Preparation and submission of bidding application |
| 217 | 1.4.1.17.5 | Evaluation and choosing the supplier |  | 5d | 2014-03-08 | 2014-03-13 | 216 |  |  | 677d | 0d | finish no earlier than 2013-11-28 | Name | 4204 | Evaluation and choosing the contractor/supplier |
| 218 | 1.4.1.17.6 | Request a quotation |  | 3d | 2014-03-13 | 2014-03-16 | 217 |  |  | 677d | 0d | start no earlier than 2014-02-11 | Name | 4204 |  |
| 219 | 1.4.1.17.7 | Approve by tender board |  | 2d | 2014-03-16 | 2014-03-18 | 218 |  |  | 677d | 0d |  | Name | 4204 |  |
| 220 | 1.4.1.17.8 | Contract signing |  | 7d | 2014-03-18 | 2014-03-25 | 219 |  |  | 677d | 93d | finish no earlier than 2013-12-10 | Name | 4204 | Contract signing with contractor/supplier |

| ID | WBS | Task | Type | Duration | Start | Finish | Predecessors | Complete | Remaining | Total slack | Free slack | Constraint | Cost | Ответственный | Text2 | Text11 |
| --- | --- | --- | --- | --- | --- | --- | --- | --- | --- | --- | --- | --- | --- | --- | --- | --- |
| 221 | 1.4.1.18 | **Anti-blowout services** |  | 15d | 2014-02-01 | 2014-02-16 |  |  |  | 714d |  |  |  | Name | Anti-blowout services |  |
| 222 | 1.4.1.18.1 | Development of draft contract |  | 5d | 2014-02-01 | 2014-02-06 |  |  |  | 714d | 0d | start no earlier than 2014-02-01 |  | Name | Development of draft contract | 421307 |
| 223 | 1.4.1.18.2 | Contract signing |  | 10d | 2014-02-06 | 2014-02-16 | 222 |  |  | 714d | 130d | start no earlier than 2012-12-18 |  | Name | Contract signing with contractor/supplier | 421307 |
| 224 | 1.4.1.19 | **Waste and mud utilization** |  | 64d | 2014-01-30 A | 2014-04-04 |  | 2% | 62.5d | 667d |  |  |  | Name | Waste utilization |  |
| 225 | 1.4.1.19.1 | Development of Technical Specification |  | 15d | 2014-01-30 A | 2014-02-14 |  | 10% | 13.5d | 667d | 0d | start no earlier than 2014-01-13 |  | Name | Development of Technical Assignment | 4212 |
| 226 | 1.4.1.19.2 | Preparation of Bidding documentation |  | 2d | 2014-02-14 | 2014-02-16 | 225 |  |  | 667d | 0d | finish no earlier than 2013-10-20 |  | Name | Preparation of Bidding documentation | 4212 |
| 227 | 1.4.1.19.3 | Announcement in media | milestone | 0d | 2014-02-16 | 2014-02-16 | 226 |  |  | 667d | 0d | finish no earlier than 2013-10-20 |  | Name | Announcement in media | 4212 |
| 228 | 1.4.1.19.4 | Preparation and submission of bidding application |  | 30d | 2014-02-16 | 2014-03-18 | 227 |  |  | 667d | 0d | finish no earlier than 2013-11-19 |  | Name | Preparation and submission of bidding application | 4212 |
| 229 | 1.4.1.19.5 | Evaluation and choosing the contractor |  | 5d | 2014-03-18 | 2014-03-23 | 228 |  |  | 667d | 0d | finish no earlier than 2013-11-28 |  | Name | Evaluation and choosing the contractor/supplier | 4212 |
| 230 | 1.4.1.19.6 | Request a quotation |  | 3d | 2014-03-23 | 2014-03-26 | 229 |  |  | 667d | 0d | start no earlier than 2013-11-28 |  | Name |  | 4212 |
| 231 | 1.4.1.19.7 | Approve by tender board |  | 2d | 2014-03-26 | 2014-03-28 | 230 |  |  | 667d | 0d |  |  | Name |  | 4212 |
| 232 | 1.4.1.19.8 | Contract signing |  | 7d | 2014-03-28 | 2014-04-04 | 231 |  |  | 667d | 83d | finish no earlier than 2013-12-10 |  | Name | Contract signing with contractor/supplier | 4212 |
| 233 | 1.4.1.20 | **H2S monitoring service** |  | 76d | 2014-01-27 A | 2014-04-13 |  | 4% | 73d | 658d |  |  |  | Name | Waste utilization |  |
| 234 | 1.4.1.20.1 | Запрос ценовых предложений |  | 30d | 2014-01-27 A | 2014-02-26 |  | 10% | 27d | 658d | 0d | start no earlier than 2014-01-27 |  | Name |  | 421306 |
| 235 | 1.4.1.20.2 | Development of Technical Specification |  | 20d | 2014-02-26 | 2014-03-18 | 234 |  |  | 658d | 0d | start no earlier than 2014-02-01 |  | Name | Development of Technical Assignment | 421306 |
| 236 | 1.4.1.20.3 | Preparation of Bidding documentation |  | 2d | 2014-03-18 | 2014-03-20 | 235 |  |  | 658d | 0d | finish no earlier than 2013-10-20 |  | Name | Preparation of Bidding documentation | 421306 |
| 237 | 1.4.1.20.4 | Announcement in media | milestone | 0d | 2014-03-20 | 2014-03-20 | 236 |  |  | 658d | 0d | finish no earlier than 2013-10-20 |  | Name | Announcement in media | 421306 |
| 238 | 1.4.1.20.5 | Preparation and submission of bidding application |  | 15d | 2014-03-20 | 2014-04-04 | 237 |  |  | 658d | 0d | finish no earlier than 2013-11-19 |  | Name | Preparation and submission of bidding application | 421306 |
| 239 | 1.4.1.20.6 | Approve by tender board |  | 2d | 2014-04-04 | 2014-04-06 | 238 |  |  | 658d | 0d |  |  | Name |  | 421306 |
| 240 | 1.4.1.20.7 | Contract signing |  | 7d | 2014-04-06 | 2014-04-13 | 239 |  |  | 658d | 74d | finish no earlier than 2013-12-10 |  | Name | Contract signing with contractor/supplier | 421306 |
| 241 | 1.4.1.21 | Container and stillazh for casing and tuning buyin |  | 30d | 2014-03-01 | 2014-03-31 |  |  |  | 841d | 0d | start no earlier than 2014-03-01 |  | Name |  | 4220 |
| 242 | 1.4.2 | **Materials and services purchasing** |  | 183d | 2014-03-06 | 2014-09-05 |  |  |  | 56d |  |  | 11,065,000 | Name | Materials and services purchasing |  |
| 243 | 1.4.2.1 | Lubricants and Tooling casing |  | 90d | 2014-03-09 | 2014-06-07 | 93 |  |  | 788d |  | start no earlier than 2012-07-01 | 300,000 | Name | Lubricants for casing string purchasing | 4220 |
| 244 | 1.4.2.2 | Casing purchasing |  | 180d | 2014-03-09 | 2014-09-05 | 93 |  |  | 53d |  | start no earlier than 2012-06-30 | 5,000,000 | Name | Casing, accessories, tubing purchasing | 4220 |
| 245 | 1.4.2.3 | Tubing purchasing |  | 180d | 2014-03-09 | 2014-09-05 | 93 |  |  | 698d |  | start no earlier than 2014-03-09 | 5,000,000 | Name |  | 422101 |
| 246 | 1.4.2.4 | Casing head and X-mas tree purchasing |  | 90d | 2014-03-06 | 2014-06-04 | 102 |  |  | 791d |  | start no earlier than 2012-06-30 | 450,000 | Name | Well-head equipment, casing head and X-mas tree purchasing | 422301 |
| 247 | 1.4.2.5 | Bits |  | 90d | 2014-03-20 | 2014-06-18 | 111 |  |  | 776d |  | finish no earlier than 2014-04-19 | 250,000 | Name |  | 420801 |
| 248 | 1.4.2.6 | Core box buying |  | 30d | 2014-05-31 | 2014-06-30 | 193 |  |  | 765d |  | start no earlier than 2014-03-03 | 20,000 | Name |  | 420801 |
| 249 | 1.4.2.7 | Container and stillazh for casing and tuning buyin |  | 15d | 2014-03-31 | 2014-04-15 | 241 |  |  | 841d |  | start no earlier than 2014-03-01 | 45,000 | Name |  | 4220 |

| ID | WBS | Task | Duration | Start | Finish | Predecessors | Total slack | Free slack | Constraint | Cost | Ответственный | Text11 |
| --- | --- | --- | --- | --- | --- | --- | --- | --- | --- | --- | --- | --- |
| 250 | 1.4.3 | **DRILLING** | 897d | 2014-01-24 | 2016-07-08 |  |  |  |  | 19,685,765 | Name |  |
| 251 | 1.4.3.1 | **Drill rig mobilization** | 127d | 2014-02-17 | 2014-06-24 |  | 0d |  |  | 2,500,000 | Name |  |
| 252 | 1.4.3.1.1 | 1st stage | 50d | 2014-02-17 | 2014-04-08 |  | 62d |  | start no earlier than 2014-02-17 | 1,900,000 | Name | 420201 |
| 253 | 1.4.3.1.2 | 2nd stage | 15d | 2014-06-09 | 2014-06-24 | 62, 252, 61 | 0d |  |  | 600,000 | Name | 420201 |
| 254 | 1.4.3.2 | **Well 1 drilling** | 141d | 2014-06-24 | 2014-11-12 |  | 0d |  |  | 4,818,000 | Name |  |
| 255 | 1.4.3.2.1 | Drilling for conductor, 20-200m | 2d | 2014-06-24 | 2014-06-26 | 339, 253, 50 | 0d |  |  | 182,500 | Name | 420202 |
| 256 | 1.4.3.2.2 | Logging, 20-200, RIH D20" Cementing, WOC, equipping casing head, BOP, pressure test | 6d | 2014-06-26 | 2014-07-02 | 255 | 0d |  |  | 164,250 | Name | 420202 |
| 257 | 1.4.3.2.3 | Drilling for intermediate casing 200-2500m | 28d | 2014-07-02 | 2014-07-30 | 256 | 0d |  |  | 912,500 | Name | 420202 |
| 258 | 1.4.3.2.4 | Logging, RIH intermediate casing D13 3/8", Cementing, WOC, BOP, pressure test | 7d | 2014-07-30 | 2014-08-06 | 257 | 0d |  |  | 191,625 | Name | 420202 |
| 259 | 1.4.3.2.5 | Drilling for intermediate casing 2500-4950m | 35d | 2014-08-06 | 2014-09-10 | 258 | 0d |  |  | 1,277,500 | Name | 420202 |
| 260 | 1.4.3.2.6 | Logging 2500-49500m, RIH intermediate casing D9 7/8+D9 5/8, cementing, WOC, rigging up BOP, pressure test (bottom of sult dome) | 8d | 2014-09-10 | 2014-09-18 | 259 | 0d |  |  | 219,000 | Name | 420202 |
| 261 | 1.4.3.2.7 | Drilling for casing 4950-5550 with core | 40d | 2014-09-18 | 2014-10-28 | 260, 244FF | 0d |  | start no earlier than 2014-06-10 | 1,460,000 | Name | 420202 |
| 262 | 1.4.3.2.8 | Logging 4950-5500m, VSP, RIH casing D7, cementing, WOC, Well Head, pressure test, CBL | 15d | 2014-10-28 | 2014-11-12 | 261 | 0d |  |  | 410,625 | Name | 420202 |
| 263 | 1.4.3.3 | Gas flaring permission | 30d | 2014-10-31 | 2014-11-30 | 262FS-12d | 612d |  |  |  | Name | 420507 |
| 264 | 1.4.3.4 | **Well test** | 43.4d | 2014-09-13 | 2014-10-26 |  |  |  |  | 1,142,450 | Name |  |
| 265 | 1.4.3.4.1 | **Object 1** | 51d | 2014-11-12 | 2015-01-02 |  | 529d |  |  | 615,025 | Name |  |
| 266 | 1.4.3.4.1.1 | Perforation | 1d | 2014-11-12 | 2014-11-13 | 262 | 557d | 0d |  | 27,375 | Name | 420202 |
| 267 | 1.4.3.4.1.2 | Tubing trip down | 1d | 2014-11-13 | 2014-11-14 | 266 | 557d | 0d |  | 36,500 | Name | 420202 |
| 268 | 1.4.3.4.1.3 | Filling up the well with Water | 1d | 2014-11-14 | 2014-11-15 | 267 | 557d | 0d | start no earlier than 2014-07-26 | 27,375 | Name | 420202 |
| 269 | 1.4.3.4.1.4 | Swabbing | 3d | 2014-11-15 | 2014-11-18 | 266, 268 | 557d | 0d |  | 82,125 | Name | 420202 |
| 270 | 1.4.3.4.1.5 | Acid Treatment | 2d | 2014-11-18 | 2014-11-20 | 269, 202 | 557d | 27d |  | 54,750 | Name | 420202 |
| 271 | 1.4.3.4.1.6 | Hydrodynamic studies | 7d | 2014-12-18 | 2014-12-25 | 270, 356 | 529d | 0d |  | 153,300 | Name | 420202 |
| 272 | 1.4.3.4.1.7 | GIS | 3d | 2014-12-25 | 2014-12-28 | 271 | 529d | 0d |  | 82,125 | Name | 420202 |
| 273 | 1.4.3.4.1.8 | Filling up the well with Drilling mud | 1d | 2014-12-28 | 2014-12-29 | 272 | 529d | 0d |  | 27,375 | Name | 420202 |
| 274 | 1.4.3.4.1.9 | Tubing trip out | 1d | 2014-12-29 | 2014-12-30 | 273 | 529d | 0d |  | 36,500 | Name | 420202 |
| 275 | 1.4.3.4.1.10 | Installing bridge plug, Tubing trip down, pressure test | 3d | 2014-12-30 | 2015-01-02 | 274 | 529d | 0d |  | 87,600 | Name | 420202 |

Notes:
- 250: Text2: Drilling
- 251: Text2: Drill rig mobilization
- 253: Text10: Winter road between main road and well location area
- 254: Text2: Well drilling
- 255: Text2: Drilling for conductor, 20-300m / Text10: 20" and 13" casing delivery on site, finishing mail road construction, Emission Permit
- 256: Text2: Cementing of conductor, WOC, equipping the wellhead (casing head, BOP)
- 257: Text2: Drilling for intermediate casing 300-1500m
- 258: Text2: Logging, RIH intermediate casing D324
- 259: Text2: Drilling for intermediate casing 1500-3000m
- 260: Text2: Logging 1500-3000m, RIH intermediate casing D245, cementing, WOC, rigging up BOP, pressure test
- 261: Text2: Drilling for casing 3000-5000 with core
- 262: Text2: Logging 3000-5000m, RIH casing D194, cementing, WOC, rigging up BOP, pressure test
- 264: Text2: Well test
- 265: Text2: Object 1
- 266: Text2: Perforation
- 267: Text2: RIH tubing to TD, filling up the well with CaCl
- 273: Text2: Killing of a well
- 274: Text2: Rinsing the well
- 275: Text2: Installing cement bridge. WOC. Pressure test.

| ID | WBS | Task | Duration | Start | Finish | Predecessors | Total slack | Free slack | Constraint | Cost | Ответственный | Text2 | Text11 |
| --- | --- | --- | --- | --- | --- | --- | --- | --- | --- | --- | --- | --- | --- |
| 276 | 1.4.3.4.2 | **Object 2** | 20d | 2015-01-02 | 2015-01-22 |  | 529d |  |  | 527,425 | Name | Object 3 |  |
| 277 | 1.4.3.4.2.1 | Tubing trip out | 1d | 2015-01-02 | 2015-01-03 | 275 | 529d | 0d |  | 27,375 | Name |  | 420202 |
| 278 | 1.4.3.4.2.2 | Perforation | 1d | 2015-01-03 | 2015-01-04 | 277 | 529d | 0d |  | 36,500 | Name | Filling up the well with CaCl | 420202 |
| 279 | 1.4.3.4.2.3 | Tubing trip down | 1d | 2015-01-04 | 2015-01-05 | 278 | 529d | 0d |  | 27,375 | Name | Packer | 420202 |
| 280 | 1.4.3.4.2.4 | Filling up the well with Water | 1d | 2015-01-05 | 2015-01-06 | 279 | 529d | 0d |  | 82,125 | Name | Perforation | 420202 |
| 281 | 1.4.3.4.2.5 | Swabbing | 3d | 2015-01-06 | 2015-01-09 | 280 | 529d | 0d | start no earlier than 2014-08-20 | 54,750 | Name |  | 420202 |
| 282 | 1.4.3.4.2.6 | Acid Treatment | 2d | 2015-01-09 | 2015-01-11 | 281 | 529d | 0d |  | 153,300 | Name |  | 420202 |
| 283 | 1.4.3.4.2.7 | Hydrodynamic studies | 7d | 2015-01-11 | 2015-01-18 | 282 | 529d | 0d | start no earlier than 2014-08-25 | 82,125 | Name |  | 420202 |
| 284 | 1.4.3.4.2.8 | GIS | 3d | 2015-01-18 | 2015-01-21 | 283 | 529d | 0d | start no earlier than 2014-09-01 | 27,375 | Name |  | 420202 |
| 285 | 1.4.3.4.2.9 | Filling up the well with Drilling mud | 1d | 2015-01-21 | 2015-01-22 | 284 | 529d | 0d |  | 36,500 | Name | Killing of a well | 420202 |
| 286 | 1.4.3.5 | **Well services** | 251d | 2014-05-12 | 2015-01-18 |  | 563d |  |  | 11,225,315 | Name | Well services |  |
| 287 | 1.4.3.5.1 | Bottom hole assemblies | 145d | 2014-06-26 | 2014-11-18 | 138, 255 | 624d |  | start no earlier than 2014-04-25 | 1,800,000 | Name |  | 4210 |
| 288 | 1.4.3.5.2 | Services of casing running | 145d | 2014-06-26 | 2014-11-18 | 147, 255 | 624d |  | start no earlier than 2014-04-25 | 350,000 | Name |  | 420601 |
| 289 | 1.4.3.5.3 | Supply of technical water and diesel fuel | 185d | 2014-06-26 | 2014-12-28 | 220, 255 | 584d |  | start no earlier than 2014-04-25 | 2,100,000 | Name | Supply of technical water and diesel fuel | 4204 |
| 290 | 1.4.3.5.4 | Drilling mud, chemicals, engineering | 185d | 2014-06-26 | 2014-12-28 | 232, 255 | 584d |  | start no earlier than 2014-04-25 | 900,000 | Name | Drilling mud, chemicals, engineering | 420901 |
| 291 | 1.4.3.5.5 | Cementing of casings | 145d | 2014-06-26 | 2014-11-18 | 129, 255 | 624d |  | start no earlier than 2014-04-25 | 1,200,000 | Name | Cementing of production casings | 4207 |
| 292 | 1.4.3.5.6 | Waste and mud utilization | 185d | 2014-06-26 | 2014-12-28 | 232, 255 | 584d |  | start no earlier than 2014-04-25 | 600,000 | Name | Moving out used mud and drill cuttings | 4212 |
| 293 | 1.4.3.5.7 | Mud logging station | 145d | 2014-06-26 | 2014-11-18 | 183, 255 | 624d |  | start no earlier than 2014-04-25 | 250,000 | Name | Mud logging station | 420503 |
| 294 | 1.4.3.5.8 | Blowout prevention | 185d | 2014-06-26 | 2014-12-28 | 223, 255 | 584d |  | start no earlier than 2014-04-25 | 180,000 | Name | Blowout prevention | 421307 |
| 295 | 1.4.3.5.9 | Logging, Testing, swabbing etc (in hole) | 185d | 2014-06-26 | 2014-12-28 | 165, 255 | 584d |  | start no earlier than 2014-04-25 | 1,475,315 | Name | Logging | 420501 |
| 296 | 1.4.3.5.10 | Coring | 40d | 2014-09-18 | 2014-10-28 | 261SS | 645d |  | start no earlier than 2014-05-30 | 150,000 | Name |  | 420504 |
| 297 | 1.4.3.5.11 | Well Testing (surface) | 30d | 2014-12-19 | 2015-01-18 | 271SS, 283FF, 211 | 563d |  | start no earlier than 2014-08-01 | 400,000 | Name |  | 430301 |
| 298 | 1.4.3.5.12 | Acid Treatment | 27d | 2014-12-15 | 2015-01-11 | 270SS, 282FF | 570d |  | start no earlier than 2014-09-19 | 300,000 | Name |  | 421501 |
| 299 | 1.4.3.5.13 | Special transport | 185d | 2014-06-26 | 2014-12-28 | 156, 255 | 584d |  | start no earlier than 2014-04-25 | 500,000 | Name |  | 4214 |
| 300 | 1.4.3.5.14 | Drilling supervising | 243d | 2014-05-12 | 2015-01-10 | 255FS-45d | 571d |  | start no earlier than 2014-03-31 | 650,000 | Name |  | 4203 |
| 301 | 1.4.3.5.15 | H2S monitoring service | 185d | 2014-06-26 | 2014-12-28 | 240, 255 | 584d |  | start no earlier than 2014-04-25 | 370,000 | Name |  | 421306 |
| 302 | 1.4.3.6 | Move to new location | 15d | 2015-06-20 | 2015-07-05 | 377 | 0d |  |  |  | Name |  |  |
| 303 | 1.4.3.7 | Well 2 drilling | 145d | 2015-07-05 | 2015-11-27 | 302 | 0d |  |  |  | Name |  |  |
| 304 | 1.4.3.8 | Well test | 90d | 2015-11-27 | 2016-02-25 | 303 | 160d |  |  |  | Name |  |  |
| 305 | 1.4.3.9 | Move to new location | 15d | 2015-11-27 | 2015-12-12 | 303 | 0d |  |  |  | Name |  |  |
| 306 | 1.4.3.10 | Well 3 drilling | 145d | 2015-12-12 | 2016-05-05 | 305 | 0d |  |  |  | Name |  |  |
| 307 | 1.4.3.11 | Well test | 90d | 2016-05-05 | 2016-08-03 | 306 | 0d |  |  |  | Name |  |  |
| 308 | 1.4.3.12 | Demobilization | 30d | 2016-05-05 | 2016-06-04 | 306 | 60d |  |  |  | Name | Demobilization |  |

| ID | WBS | Task | Type | Duration | Start | Finish | Predecessors | Complete | Remaining | Total slack | Free slack | Constraint | Cost | Actual cost | Ответственный | Text11 |
| --- | --- | --- | --- | --- | --- | --- | --- | --- | --- | --- | --- | --- | --- | --- | --- | --- |
| 309 | 1.5 | **Surveys and analisis** |  | 112d | 2014-10-28 | 2015-02-17 |  |  |  | 533d |  |  | 336,215 |  | Name |  |
| 310 | 1.5.1 | VSP |  | 2d | 2014-10-30 | 2014-11-01 | 261FS+2d |  |  | 611d | 0d |  | 180,000 |  | Name | 420507 |
| 311 | 1.5.2 | VSP data interpretation |  | 30d | 2014-11-01 | 2014-12-01 | 310 |  |  | 611d |  |  | 23,215 |  | Name | 3002 |
| 312 | 1.5.3 | Core analysis (~100m) |  | 90d | 2014-10-28 | 2015-01-26 | 261, 192 |  |  | 555d |  | finish no earlier than 2014-09-29 | 100,000 |  | Name | 420504 |
| 313 | 1.5.4 | Oil and Gas Analises |  | 30d | 2015-01-18 | 2015-02-17 | 271, 283, 192 |  |  | 533d |  |  | 33,000 |  | Name | 420506 |
| 314 | 1.6 | **Projects, Permissions** |  | 571d | 2013-11-26 A | 2015-06-20 |  | 4% | 548.44d | 410d |  |  | 296,500 | 70,072 | Name |  |
| 315 | 1.6.1 | **Development of wells construction project, including EIA** |  | 139d | 2013-11-26 A | 2014-04-14 |  | 31% | 95.81d | 842d |  |  | 71,500 | 70,072 | Name |  |
| 316 | 1.6.1.1 | Tender procedure, contract signing | milestone | 0d | 2013-11-26 A | 2013-11-26 A |  | 100% |  |  |  | start no earlier than 2013-11-26 | 100 | 100 | Name | 4102 |
| 317 | 1.6.1.2 | Development of project (design) |  | 65d | 2013-11-26 A | 2014-01-30 | 316 | 98% | 1.3d | 64d | 0d |  | 71,400 | 69,972 | Name | 4102 |
| 318 | 1.6.1.3 | Public hearings |  | 30d | 2014-01-30 | 2014-03-01 | 317 |  |  | 886d |  |  |  |  | Name | 4102 |
| 319 | 1.6.1.4 | **Local approval** |  | 21d | 2014-01-30 | 2014-02-20 |  |  |  | 64d |  |  |  |  | Name |  |
| 320 | 1.6.1.4.1 | Sanitary and Epidemiological Service |  | 7d | 2014-01-30 | 2014-02-06 | 317 |  |  | 909d |  |  |  |  | Name | 4102 |
| 321 | 1.6.1.4.2 | Protection of mineral resources |  | 7d | 2014-01-30 | 2014-02-06 | 317 |  |  | 71d | 7d |  |  |  | Name | 4102 |
| 322 | 1.6.1.4.3 | Independent examination of industrial safety |  | 7d | 2014-01-30 | 2014-02-06 | 317 |  |  | 64d | 0d |  |  |  | Name | 4102 |
| 323 | 1.6.1.4.4 | Department of Emergency Situations |  | 7d | 2014-02-06 | 2014-02-13 | 322 |  |  | 64d | 0d |  |  |  | Name | 4102 |
| 324 | 1.6.1.4.5 | Environmental control |  | 7d | 2014-02-13 | 2014-02-20 | 321, 323 |  |  | 64d | 0d |  |  |  | Name | 4102 |
| 325 | 1.6.1.5 | **Astana approval** |  | 60d | 2014-02-13 | 2014-04-14 |  |  |  | 71d |  |  |  |  | Name |  |
| 326 | 1.6.1.5.1 | Ministry of enviroment and water recourses |  | 15d | 2014-02-20 | 2014-03-07 | 324 |  |  | 64d | 0d |  |  |  | Name | 4102 |
| 327 | 1.6.1.5.2 | Ministry of Emergensy situation |  | 30d | 2014-02-13 | 2014-03-15 | 323 |  |  | 842d | 0d |  |  |  | Name | 4102 |
| 328 | 1.6.1.5.3 | Department of Oil and Gas of the Ministry |  | 30d | 2014-03-15 | 2014-04-14 | 327, 326 |  |  | 842d |  |  |  |  | Name | 4102 |
| 329 | 1.6.2 | **Operative reserve estimation (Tender)** |  | 54d | 2014-06-16 | 2014-08-09 |  |  |  | 26d |  |  |  |  | Name |  |
| 330 | 1.6.2.1 | Development of Technical Specification |  | 5d | 2014-06-16 | 2014-06-21 | 204FS+20d |  |  | 26d | 0d | start no earlier than 2014-02-02 |  |  | Name | 3009 |
| 331 | 1.6.2.2 | Preparation of Bidding documentation |  | 2d | 2014-06-21 | 2014-06-23 | 330 |  |  | 26d | 0d | finish no earlier than 2014-02-10 |  |  | Name | 3009 |
| 332 | 1.6.2.3 | Announcement in media | milestone | 0d | 2014-06-23 | 2014-06-23 | 331 |  |  | 65d | 0d | finish no earlier than 2014-02-10 |  |  | Name | 3009 |
| 333 | 1.6.2.4 | Preparation and submission of bidding application |  | 30d | 2014-06-23 | 2014-07-23 | 332 |  |  | 65d | 0d | finish no earlier than 2014-03-12 |  |  | Name | 3009 |
| 334 | 1.6.2.5 | Evaluation and choosing the contractor |  | 7d | 2014-07-23 | 2014-07-30 | 333 |  |  | 65d | 0d | finish no earlier than 2014-03-21 |  |  | Name | 3009 |
| 335 | 1.6.2.6 | Request a quotation |  | 3d | 2014-07-30 | 2014-08-02 | 334 |  |  | 65d | 0d | finish no earlier than 2014-03-13 |  |  | Name | 3009 |
| 336 | 1.6.2.7 | Contract signing |  | 7d | 2014-08-02 | 2014-08-09 | 335 |  |  | 65d |  | finish no earlier than 2014-04-02 |  |  | Name | 3009 |

Notes:
- 312: Text2: Core analysis
- 314: Text2: Projects, Permissions
- 315: Text2: Development to exploration wells construction project, including EIA
- 316: Text2: Tender procedure, contract signing
- 317: Text2: Development of project (design), approval at governmental authorities
- 326: Emmition permit (Drilling Contractor)

| ID | WBS | Task | Duration | Start | Finish | Predecessors | Total slack | Free slack | Constraint | Cost | Ответственный | Text11 |
| --- | --- | --- | --- | --- | --- | --- | --- | --- | --- | --- | --- | --- |
| 337 | 1.6.3 | **Emission Permit** | 48d | 2014-03-04 | 2014-04-21 |  | 64d |  |  |  | Name |  |
| 338 | 1.6.3.1 | Emission Permit application development | 3d | 2014-03-04 | 2014-03-07 | 326FF | 64d | 0d | finish no earlier than 2014-01-30 |  | Name |  |
| 339 | 1.6.3.2 | Emission Permit approval | 45d | 2014-03-07 | 2014-04-21 | 338 | 64d |  |  |  | Name |  |
| 340 | 1.6.4 | **Environmental Action Plan** | 30d | 2014-03-05 | 2014-04-04 |  | 852d |  |  |  | Name |  |
| 341 | 1.6.4.1 | EAP Development | 10d | 2014-03-05 | 2014-03-15 |  | 852d | 0d | start no earlier than 2014-03-05 |  | Name | 430203 |
| 342 | 1.6.4.2 | EAP approval internally | 3d | 2014-03-15 | 2014-03-18 | 341 | 869d |  |  |  | Name | 430203 |
| 343 | 1.6.4.3 | Public hearings for EAP, including announcement in Mass media | 30d | 2014-03-05 | 2014-04-04 | 341SS | 852d |  |  |  | Name | 430203 |
| 344 | 1.6.5 | **Environmental Control Programme** | 58d | 2014-01-20 | 2014-03-19 |  | 868d |  |  |  | Name |  |
| 345 | 1.6.5.1 | ECP Development | 55d | 2014-01-20 | 2014-03-16 |  | 868d | 0d | start no earlier than 2014-01-20 |  | Name | 43020406 |
| 346 | 1.6.5.2 | ECP approval internally | 3d | 2014-03-16 | 2014-03-19 | 345 | 868d |  |  |  | Name | 43020406 |
| 347 | 1.6.6 | **Waste management** | 65d | 2014-02-10 | 2014-04-16 |  | 840d |  |  | 10,000 | Name |  |
| 348 | 1.6.6.1 | Request a quotation | 30d | 2014-02-10 | 2014-03-12 |  | 840d | 0d | start no earlier than 2014-02-10 |  | Name | 43020406 |
| 349 | 1.6.6.2 | Waste passportization | 30d | 2014-03-12 | 2014-04-11 | 348 | 840d | 0d |  | 5,000 | Name | 43020406 |
| 350 | 1.6.6.3 | Waste management programme development | 30d | 2014-03-17 | 2014-04-16 | 349SS+5d | 840d |  |  | 5,000 | Name | 43020406 |
| 351 | 1.6.7 | **Gas flaring Permit** | 48d | 2014-10-31 | 2014-12-18 |  | 529d |  |  |  | Name |  |
| 352 | 1.6.7.1 | Well testing programme approval with Geology Inspection | 15d | 2014-10-31 | 2014-11-15 | 262FS-12d | 529d | 0d | start no earlier than 2014-03-30 |  | Name | 43020406 |
| 353 | 1.6.7.2 | Well testing programme approval with Emergency situation department | 15d | 2014-10-31 | 2014-11-15 | 262FS-12d | 529d | 0d | start no earlier than 2014-03-30 |  | Name | 43020406 |
| 354 | 1.6.7.3 | Weel testing programme approval with Ecology | 15d | 2014-10-31 | 2014-11-15 | 262FS-12d | 529d | 0d | start no earlier than 2014-03-30 |  | Name | 43020406 |
| 355 | 1.6.7.4 | Gas flaring permit application | 3d | 2014-11-15 | 2014-11-18 | 352, 353, 354 | 529d | 0d |  |  | Name | 43020406 |
| 356 | 1.6.7.5 | Gas flaring permit approval in MOG | 30d | 2014-11-18 | 2014-12-18 | 355 | 529d | 0d |  |  | Name | 43020406 |
| 357 | 1.6.8 | **Industrial Security Documents** | 80d | 2014-01-30 | 2014-04-20 |  | 836d |  |  | 35,000 | Name |  |
| 358 | 1.6.8.1 | Request a quotation | 30d | 2014-01-30 | 2014-03-01 | 317 | 836d | 0d | start no earlier than 2014-01-30 |  | Name | 430203 |
| 359 | 1.6.8.2 | Develop documentation for industrial safety | 30d | 2014-03-01 | 2014-03-31 | 358 | 836d | 0d |  | 35,000 | Name | 430203 |
| 360 | 1.6.8.3 | Registration in ES and Ak Beren | 20d | 2014-03-31 | 2014-04-20 | 359 | 836d |  |  |  | Name | 430203 |

| ID | WBS | Task | Type | Duration | Start | Finish | Predecessors | Total slack | Free slack | Constraint | Cost | Ответственный | Text11 |
| --- | --- | --- | --- | --- | --- | --- | --- | --- | --- | --- | --- | --- | --- |
| 361 | 1.6.9 | **Personal Protective Equipment** |  | 60d | 2014-03-01 | 2014-04-30 |  | 826d |  |  | 20,000 | Name |  |
| 362 | 1.6.9.1 | Request a quotation |  | 30d | 2014-03-01 | 2014-03-31 |  | 826d | 0d | start no earlier than 2014-03-01 |  | Name | 430203 |
| 363 | 1.6.9.2 | Perchasing |  | 30d | 2014-03-31 | 2014-04-30 | 362 | 826d |  |  | 20,000 | Name | 430203 |
| 364 | 1.6.10 | Operative reserve estimation |  | 90d | 2014-10-13 | 2015-01-11 | 262FS-30d, 336 | 0d |  |  |  | Name | 3009 |
| 365 | 1.6.11 | Reserve approval |  | 20d | 2015-01-11 | 2015-01-31 | 364 | 550d |  |  |  | Name | 3009 |
| 366 | 1.6.12 | **Project of appraisal work (Tender)** |  | 56d | 2014-08-22 | 2014-10-17 |  | 26d |  |  |  | Name |  |
| 367 | 1.6.12.1 | Development of Technical Specification |  | 7d | 2014-08-22 | 2014-08-29 | 331FS+60d | 26d | 0d | start no earlier than 2014-02-13 |  | Name | 3050 |
| 368 | 1.6.12.2 | Preparation of Bidding documentation |  | 2d | 2014-08-29 | 2014-08-31 | 367 | 26d | 0d | finish no earlier than 2014-02-10 |  | Name | 3050 |
| 369 | 1.6.12.3 | Announcement in media | milestone | 0d | 2014-08-31 | 2014-08-31 | 368 | 26d | 0d | finish no earlier than 2014-02-10 |  | Name | 3050 |
| 370 | 1.6.12.4 | Preparation and submission of bidding application |  | 30d | 2014-08-31 | 2014-09-30 | 369 | 26d | 0d | finish no earlier than 2014-03-12 |  | Name | 3050 |
| 371 | 1.6.12.5 | Evaluation and choosing the contractor |  | 7d | 2014-09-30 | 2014-10-07 | 370 | 26d | 0d | finish no earlier than 2014-03-21 |  | Name | 3050 |
| 372 | 1.6.12.6 | Request a quotation |  | 3d | 2014-10-07 | 2014-10-10 | 371 | 26d | 0d | finish no earlier than 2014-03-24 |  | Name | 3050 |
| 373 | 1.6.12.7 | Contract signing |  | 7d | 2014-10-10 | 2014-10-17 | 372 | 26d |  | finish no earlier than 2014-04-02 |  | Name | 3050 |
| 374 | 1.6.13 | Project of appraisal work |  | 100d | 2014-11-12 | 2015-02-20 | 364FS-60d, 373 | 0d |  |  | 80,000 | Name | 3050 |
| 375 | 1.6.14 | Examination of the project appraisal work |  | 15d | 2015-02-20 | 2015-03-07 | 374 | 0d |  |  |  | Name | 3050 |
| 376 | 1.6.15 | New contract signing |  | 15d | 2015-03-07 | 2015-03-22 | 375 | 0d |  |  |  | Name | 3050 |
| 377 | 1.6.16 | Development of wells construction project, including EIA |  | 90d | 2015-03-22 | 2015-06-20 | 376 | 0d |  | start no earlier than 2014-09-29 |  | Name | 4102 |
| 378 | 1.6.17 | **EIA to the project of appraisal work (Tender)** |  | 70d | 2014-08-20 | 2014-10-29 |  | 554d |  |  |  | Name |  |
| 379 | 1.6.17.1 | Development of Technical Specification |  | 11d | 2014-08-20 | 2014-08-31 | 330FS+60d | 554d | 0d | start no earlier than 2014-02-13 |  | Name | 4102 |
| 380 | 1.6.17.2 | Preparation of Bidding documentation |  | 8d | 2014-08-31 | 2014-09-08 | 379 | 554d | 0d | finish no earlier than 2014-02-10 |  | Name | 4102 |
| 381 | 1.6.17.3 | Announcement in media | milestone | 0d | 2014-09-08 | 2014-09-08 | 380 | 554d | 0d | finish no earlier than 2014-02-10 |  | Name | 4102 |
| 382 | 1.6.17.4 | Preparation and submission of bidding application |  | 30d | 2014-09-08 | 2014-10-08 | 381 | 554d | 0d | finish no earlier than 2014-03-12 |  | Name | 4102 |
| 383 | 1.6.17.5 | Evaluation and choosing the contractor |  | 9d | 2014-10-08 | 2014-10-17 | 382 | 554d | 0d | finish no earlier than 2014-03-21 |  | Name | 4102 |
| 384 | 1.6.17.6 | Contract signing |  | 12d | 2014-10-17 | 2014-10-29 | 383 | 554d | 24d | finish no earlier than 2014-04-02 |  | Name | 4102 |
| 385 | 1.6.18 | EIA to the project of appraisal work |  | 90d | 2014-11-22 | 2015-02-20 | 374FS-90d, 384 | 530d |  |  | 40,000 | Name | 4102 |

Notes:
- 377: Text2: Development to exploration wells construction project, including EIA

| ID | WBS | Task | Type | Duration | Start | Finish | Predecessors | Total slack | Free slack | Constraint | Cost | Ответственный | Text11 |
| --- | --- | --- | --- | --- | --- | --- | --- | --- | --- | --- | --- | --- | --- |
| 386 | 1.6.19 | **Gas utilization program (Tender)** |  | 70d | 2014-09-08 | 2014-11-17 |  | 454d |  |  |  | Name |  |
| 387 | 1.6.19.1 | Development of Technical Specification |  | 11d | 2014-09-08 | 2014-09-19 | 367FS+10d | 454d | 0d | start no earlier than 2014-02-13 |  | Name | 430203 |
| 388 | 1.6.19.2 | Preparation of Bidding documentation |  | 8d | 2014-09-19 | 2014-09-27 | 387 | 535d | 0d | finish no earlier than 2014-02-10 |  | Name | 430203 |
| 389 | 1.6.19.3 | Announcement in media | milestone | 0d | 2014-09-27 | 2014-09-27 | 388 | 535d | 0d | finish no earlier than 2014-02-10 |  | Name | 430203 |
| 390 | 1.6.19.4 | Preparation and submission of bidding application |  | 30d | 2014-09-27 | 2014-10-27 | 389 | 535d | 0d | finish no earlier than 2014-03-12 |  | Name | 430203 |
| 391 | 1.6.19.5 | Evaluation and choosing the contractor |  | 9d | 2014-10-27 | 2014-11-05 | 390 | 535d | 0d | finish no earlier than 2014-03-21 |  | Name | 430203 |
| 392 | 1.6.19.6 | Contract signing |  | 12d | 2014-11-05 | 2014-11-17 | 391 | 535d | 5d | finish no earlier than 2014-04-02 |  | Name | 430203 |
| 393 | 1.6.20 | Gas utilization program |  | 90d | 2014-11-22 | 2015-02-20 | 374FS-90d, 392 | 530d |  |  | 40,000 | Name | 430203 |
| 394 | 1.6.21 | **Subsurface condition monitoring program** |  | 70d | 2014-09-29 | 2014-12-08 |  | 454d |  |  |  | Name |  |
| 395 | 1.6.21.1 | Development of Technical Specification |  | 11d | 2014-09-29 | 2014-10-10 | 387FS+10d | 454d | 0d | start no earlier than 2014-02-13 |  | Name | 430203 |
| 396 | 1.6.21.2 | Preparation of Bidding documentation |  | 8d | 2014-10-10 | 2014-10-18 | 395 | 454d | 0d | finish no earlier than 2014-02-10 |  | Name | 430203 |
| 397 | 1.6.21.3 | Announcement in media | milestone | 0d | 2014-10-18 | 2014-10-18 | 396 | 454d | 0d | finish no earlier than 2014-02-10 |  | Name | 430203 |
| 398 | 1.6.21.4 | Preparation and submission of bidding application |  | 30d | 2014-10-18 | 2014-11-17 | 397 | 454d | 0d | finish no earlier than 2014-03-12 |  | Name | 430203 |
| 399 | 1.6.21.5 | Evaluation and choosing the contractor |  | 9d | 2014-11-17 | 2014-11-26 | 398 | 454d | 0d | finish no earlier than 2014-03-21 |  | Name | 430203 |
| 400 | 1.6.21.6 | Contract signing |  | 12d | 2014-11-26 | 2014-12-08 | 399 | 454d | 0d | finish no earlier than 2014-04-02 |  | Name | 430203 |
| 401 | 1.6.22 | Subsurface condition monitoring program |  | 90d | 2015-02-06 | 2015-05-07 | 400FS+60d | 454d |  | start no earlier than 2014-07-01 |  | Name |  |
| 402 | 1.6.23 | Request for postponement of MNG return contract territory |  | 30d | 2015-01-22 | 2015-02-21 | 285 | 529d |  | start no earlier than 2014-07-01 |  | Name |  |
