# График проектирования дороги и площадок_Актуальный

Schedule from MS Project, 2014-02-24 to 2014-08-02, status date 2014-02-10, 24 hours a day, A marks actual dates.
DG Win&Soft

## Calendars

- Стандартный: Mon-Fri 09:00-13:00, 14:00-18:00; Sat-Sun off. Exceptions (off unless hours are given): 2014-07-24.
- 24 часа: Mon-Sun 00:00-24:00.

## Schedule

| ID | WBS | Task | Duration | Start | Finish | Predecessors | Complete | Remaining | Total slack | Constraint | Calendar |
| --- | --- | --- | --- | --- | --- | --- | --- | --- | --- | --- | --- |
| 1 | 1 | **Земля и проектирование** | 38d? | 2014-02-24 A | 2014-08-02 |  | 81% | 7.14d? | 0d |  | Стандартный |
| 2 | 1.1 | **Отвод земельного участка** | 150.33d | 2014-02-24 A | 2014-07-24 |  | 73% | 40.29d | 9d |  |  |
| 3 | 1.1.1 | Письмо Акиму Бурлинского района о возобновлении работ по предоставлению земельного участка | 0.67d | 2014-02-24 A | 2014-02-25 A |  | 100% |  |  | start no earlier than 2014-02-24 |  |
| 4 | 1.1.2 | Изготовление акта выбора земельного участка с бегунком | 0.67d | 2014-02-26 A | 2014-02-27 A | 3 | 100% |  |  | start no earlier than 2014-02-03 |  |
| 5 | 1.1.3 | Согласование с Гос. органами Акта выбора земельного участка | 3d | 2014-02-28 A | 2014-03-03 A | 4 | 100% |  |  | start no earlier than 2014-02-04 |  |
| 6 | 1.1.4 | Ожидание подписи председателя комиссии | 10d | 2014-03-03 | 2014-03-13 | 5 |  |  | 142.33d |  |  |
| 7 | 1.1.5 | Заключение зем. комиссии | 1d | 2014-04-22 A | 2014-04-23 A | 6 | 100% |  |  | finish no earlier than 2014-01-24 |  |
| 8 | 1.1.6 | Разработка Зем. проекта | 6.67d | 2014-04-02 A | 2014-04-09 A | 7FS-5.67d | 100% |  |  | finish no earlier than 2014-01-30 |  |
| 9 | 1.1.7 | Согласование с Гос. органами Зем.проекта | 7d | 2014-04-30 A | 2014-05-07 A | 8, 7 | 100% |  |  | finish no earlier than 2014-05-28 |  |
| 10 | 1.1.8 | Разработка Проекта рекультивации | 8d | 2014-04-14 A | 2014-04-22 A | 4, 7FS-10d | 100% |  |  | start no earlier than 2014-04-14 |  |
| 11 | 1.1.9 | Согласование с Гос. органми проекта рекультивации (СЭС заключение) | 10d | 2014-05-16 A | 2014-05-26 | 10 | 17% | 8.33d | 68.33d |  |  |
| 12 | 1.1.10 | Обьявление в газету | 0.67d | 2014-05-02 A | 2014-05-03 A | 10FS-3.33d | 100% |  |  |  |  |
| 13 | 1.1.11 | Разработка раздела ООС на Проект рекультивации | 1.67d | 2014-05-07 A | 2014-05-09 A | 10FS-3.33d | 100% |  |  | start no earlier than 2014-05-07 |  |
| 14 | 1.1.12 | согласование Проекта рекультивации с департаментом природоохраны ЗКО | 1.67d | 2014-05-29 A | 2014-05-31 A | 11, 12, 13 | 100% |  |  | finish no earlier than 2014-06-04 |  |
| 15 | 1.1.13 | Постановление Акима Бурлинского района | 3d | 2014-05-29 A | 2014-06-01 A | 9 | 100% |  |  |  |  |
| 16 | 1.1.14 | Постановление Акима области | 5d | 2014-06-11 A | 2014-06-16 A | 15 | 100% |  |  | finish no earlier than 2014-07-01 |  |
| 17 | 1.1.15 | Окончательное оформление Земпроекта с вложением Постановления Акима ЗКО | 0.67d | 2014-07-02 A | 2014-07-03 A | 16 | 100% |  |  |  |  |
| 18 | 1.1.16 | Окончательное офрмление Проекта рекультивации | 0.67d | 2014-07-04 A | 2014-07-05 A | 17 | 100% |  |  |  |  |
| 19 | 1.1.17 | Согласование Проекта рекультивации с управлением зем.отношении Бурлинского района | 4.33d | 2014-07-08 A | 2014-07-12 A | 18 | 100% |  |  |  |  |
| 20 | 1.1.18 | Заключение Договора аренды земельного участка с Акиматом ЗКО | 2d | 2014-07-02 A | 2014-07-04 A | 16 | 100% |  |  |  |  |
| 21 | 1.1.19 | Заключение Договора с НПЦ Гипрозем в ЗКО на изготовление Госакта на землю | 1.33d | 2014-07-10 A | 2014-07-11 A | 20 | 100% |  |  |  |  |
| 22 | 1.1.20 | Подготовка и передача документов в НПЦ Гипрозем через ЦОН | 1.33d | 2014-07-16 A | 2014-07-17 A | 21, 17 | 100% |  |  |  |  |
| 23 | 1.1.21 | Получение в ЦОНе Госакта на землю | 2.33d | 2014-07-22 A | 2014-07-24 | 22 | 63% | 0.88d | 9d |  |  |
| 24 | 1.2 | **Проектирование** | 76.33d? | 2014-02-25 A | 2014-05-12 A |  | 100% |  |  |  |  |
| 25 | 1.2.1 | Инженерно-геодезические изыскания | 5d | 2014-02-25 A | 2014-03-02 A |  | 100% |  |  | start no earlier than 2014-02-25 |  |
| 26 | 1.2.2 | Инженерно-геологические изыскания | 13.33d | 2014-03-03 A | 2014-03-16 A | 25FS-4.33d | 100% |  |  | start no earlier than 2014-03-03 |  |
| 27 | 1.2.3 | Графическая часть | 12.33d | 2014-03-18 A | 2014-03-30 A | 25 | 100% |  |  |  |  |
| 28 | 1.2.4 | Пояснительная записка | 3.33d | 2014-04-25 A | 2014-04-28 A | 25, 27FS-3d | 100% |  |  |  |  |
| 29 | 1.2.5 | Сметная документация | 3.33d | 2014-05-09 A | 2014-05-12 A | 27, 28, 26 | 100% |  |  |  |  |
| 30 | 1.2.6 | Раздел ООС | 1.67d | 2014-05-02 A | 2014-05-04 A | 28FS-1.67d | 100% |  |  |  |  |
| 31 | 1.2.7 | Обьявление в газету | 0.33d? | 2014-05-09 A | 2014-05-09 A | 28 | 100% |  |  |  |  |
| 32 | 1.2.8 | Согласование с СЭС | 0.67d | 2014-05-09 A | 2014-05-10 A | 27, 28, 7 | 100% |  |  | start no earlier than 2014-04-22 |  |
| 33 | 1.3 | Заключение по Пром безопасности с согласованием ЧС | 3.33d | 2014-07-02 A | 2014-07-05 A | 16, 28 | 100% |  |  |  |  |
| 34 | 1.4 | Экологическое заключение от Департамента природоохраны ЗКО | 6.33d | 2014-07-02 A | 2014-07-08 | 16, 27, 28, 30, 31 | 97% | 0.21d | 20.67d |  |  |
| 35 | 1.5 | Согласование с Обл ГАИ | 0.67d | 2014-07-24 A | 2014-07-25 A | 27, 28, 34FS-1d | 100% |  |  | start no earlier than 2014-03-25 |  |
| 36 | 1.6 | Заключение независимой строительной экспертизы | 4.33d | 2014-07-29 | 2014-08-02 | 16, 32, 35, 33, 34 |  |  | 0d | start no earlier than 2014-07-29 |  |
